# IMPACT

Schedule from MS Project, 2000-05-24 to 2005-06-28, status date 2003-08-31, A marks actual dates.
IMPACT Suite Development Schedule
NASA GSFC
Status Date: 08/31/2003 / Baseline Date: 01/31/2003 R1

## Calendars

- Standard w/ 10 Gov't Holidays: Mon-Fri 08:00-12:00, 13:00-17:00; Sat-Sun off. Exceptions (off unless hours are given): 2000-05-29, 2000-07-04, 2000-09-04, 2000-10-09, 2000-11-13, 2000-11-23, 2000-12-25, 2001-01-01, 2001-01-15, 2001-02-19, 2001-05-28, 2001-07-04, 2001-09-03, 2001-10-08, 2001-11-12, 2001-11-22, 2001-12-25, 2002-01-01, 2002-01-14, 2002-02-18, 2002-05-27, 2002-07-04, 2002-09-02, 2002-10-07, 2002-11-11, 2002-11-28, 2002-12-25, 2003-01-01, 2003-01-13, 2003-02-17, 2003-05-26, 2003-07-04, 2003-09-01, 2003-10-06, 2003-11-10, 2003-11-27, 2003-12-25, 2004-01-01, 2004-01-12, 2004-02-16, 2004-05-31, 2004-07-05, 2004-09-06, 2004-10-11, 2004-11-08, 2004-11-25, 2004-12-24, 2004-12-31, 2005-01-17, 2005-02-21, 2005-05-30.

## Schedule

| ID | WBS | Task | Type | Duration | Start | Finish | Predecessors | Complete | Remaining | Baseline start | Baseline finish | Baseline duration | Total slack | Free slack | Constraint | Text11 | Text12 | Text28 | Text20 | Text21 | Text22 | Text23 |
| --- | --- | --- | --- | --- | --- | --- | --- | --- | --- | --- | --- | --- | --- | --- | --- | --- | --- | --- | --- | --- | --- | --- |
| 1 | 1 | **Management** |  | 1015d | 2000-05-24 A | 2004-06-09 |  | 99% | 0d | 2000-05-24 | 2004-06-15 | 1019d | 263.76d |  |  | STEREO | IMPACT | UC-B |  |  |  |  |
| 2 | 1.1 | **Milestones** |  | 1015d | 2000-05-24 A | 2004-06-09 |  | 99% | 0d | 2000-05-24 | 2004-06-15 | 1019d | 263.76d |  |  | STEREO | IMPACT | UC-B |  |  |  |  |
| 3 | 1.1.1 | Instrument SRR | milestone | 0d | 2000-05-24 A | 2000-05-24 A |  | 100% |  | 2000-05-24 | 2000-05-24 | 0d |  |  | start no earlier than 2000-05-24 | STEREO | IMPACT | UC-B |  |  |  |  |
| 4 | 2.1.1.1 | STE Aperture Design |  | 58d | 2000-05-26 A | 2000-08-17 A | 3FS+2d | 100% |  | 2000-05-26 | 2000-08-17 | 58d |  |  |  | STEREO | IMPACT |  |  |  |  |  |
| 5 | 3.1.2.1 | STE Charge Sensitive Amplifier Design |  | 318d | 2000-05-26 A | 2001-08-30 A | 3FS+2d | 100% |  | 2000-05-26 | 2001-08-30 | 318d |  |  |  | STEREO | IMPACT |  |  |  |  |  |
| 6 | 3.1.1.1.2 | Procure STE ETU Detector |  | 318d | 2000-05-26 A | 2001-08-30 A | 3FS+2d | 100% |  | 2000-05-26 | 2001-08-30 | 318d |  |  |  | STEREO | IMPACT |  |  |  |  |  |
| 7 | 1.1.5 | Instrument PDR | milestone | 1d | 2001-09-11 A | 2001-09-11 A |  | 100% |  | 2001-09-11 | 2001-09-11 | 1d |  |  | start no earlier than 2001-09-11 | STEREO | IMPACT | UC-B | PDR | PDR |  |  |
| 8 | 2.1.7 | Collect & verify SEP power requirements |  | 2d | 2001-09-11 A | 2001-09-12 A | 7 | 100% |  | 2001-09-11 | 2001-09-12 | 2d |  |  |  | STEREO | IMPACT |  |  |  |  |  |
| 9 | 6.1.2.1.1 | Collect & verify SEP analog/post-reg requirements |  | 6.5d | 2002-01-02 A | 2002-12-03 A | 7FS+76d | 100% |  | 2002-01-02 | 2002-12-03 | 6.5d |  |  |  | STEREO | IMPACT |  |  |  |  |  |
| 10 | 7.1.2.1.2 | Collect & verify SEP Solid State Detector bias requirements |  | 2d | 2001-11-06 A | 2001-11-07 A | 7FS+39d | 100% |  | 2001-11-06 | 2001-11-07 | 2d |  |  |  | STEREO | IMPACT |  |  |  |  |  |
| 11 | 3.1.1.2.3 | (OBSOLETE) Procure STE FM 1 & FM 2 Detectors |  | 21d | 2003-06-02 A | 2003-06-30 A | 7 | 100% |  | 2003-04-25 | 2003-08-11 | 75d |  |  | start no earlier than 2003-05-31 | STEREO | IMPACT |  |  |  |  |  |
| 12 | 3.1.1.2.2 | Procure STE Long Lead Parts |  | 241d | 2001-09-11 A | 2003-07-29 A | 7 | 100% |  | 2001-09-11 | 2003-03-31 | 241d |  |  |  | STEREO | IMPACT |  |  |  |  |  |
| 13 | 2.2.2 | LET Vibration Analysis |  | 15d | 2003-05-01 | 2003-05-21 |  |  |  | 2003-02-03 | 2003-02-24 | 15d | 385d | 0d | start no earlier than 2003-04-30 | STEREO | IMPACT |  |  |  |  |  |
| 14 | 3.1.2.1 | Design HET Housing |  | 99d | 2002-09-03 A | 2003-10-13 |  | 81% | 18.81d | 2002-09-03 | 2003-02-24 | 34d | 32.4d |  | finish no earlier than 2003-02-24 | STEREO | IMPACT |  |  |  |  |  |
| 15 | 1.1.13 | Instrument CDR | milestone | 3d | 2002-11-20 A | 2002-11-22 A | 13FS-10d, 14 | 100% |  | 2002-11-20 | 2002-11-22 | 3d |  |  | finish no earlier than 2002-11-22 | STEREO | IMPACT | UC-B | CDR | CDR | IMPACT - Instrument CDR | Instrument CDR |
| 16 | 1.2.5.1 | Receive RFAs From Instrument CDR | milestone | 0d | 2003-03-31 A | 2003-06-30 A | 15FS+10d | 100% |  | 2003-02-01 | 2003-02-01 | 0d |  |  | start no earlier than 2003-03-31 | STEREO | IMPACT |  |  |  |  |  |
| 17 | 2.1.9 | Collect SEP power req update |  | 1d | 2003-09-29 | 2003-09-29 | 15 |  |  | 2003-06-11 | 2003-06-11 | 1d | 26d | 0d |  | STEREO | IMPACT |  |  |  |  |  |
| 18 | 6.1.2.2.2 | Collect SEP analog/post-reg requirements update |  | 1d | 2003-06-17 A | 2003-07-02 A | 15 | 100% |  | 2003-07-07 | 2003-07-07 | 1d |  |  |  | STEREO | IMPACT |  |  |  |  |  |
| 19 | 2.1.2 | Write final Software Development Plan |  | 5d | 2002-09-23 A | 2002-09-27 A | 15FS-8d | 100% |  | 2002-09-23 | 2002-09-27 | 5d |  |  |  | STEREO | IMPACT |  |  |  |  |  |
| 20 | 3.1.2.1.2.1 | Fabricate SEP FM 2 Common Electronics Enclosure |  | 15d | 2003-10-01 | 2003-10-23 | 15 |  |  | 2003-05-02 | 2003-05-22 | 15d | 62.5d | 0d |  | STEREO | IMPACT |  |  |  |  |  |
| 21 | 3.1.2.1.1.2 | Fabricate SEP FM 1 Common Electronics Enclosure |  | 15d | 2003-10-01 | 2003-10-23 | 15 |  |  | 2003-05-02 | 2003-05-22 | 15d | 62.5d | 0d |  | STEREO | IMPACT |  |  |  |  |  |
| 22 | 3.1.1.1.1 | Place Order For HET FM1, HET FM 2, HET Spare Housing |  | 2d | 2003-10-13 | 2003-10-15 | 15 |  |  | 2003-02-25 | 2003-02-26 | 2d | 32.4d |  | start no earlier than 2003-05-31 | STEREO | IMPACT |  |  |  |  |  |
| 23 | 2.1.2.2.2.1 | Fabricate STE FM 2 Box |  | 15d | 2003-09-08 | 2003-09-26 | 15 |  |  | 2003-11-20 | 2004-01-16 | 38d | 52d |  | start no earlier than 2003-09-08 | STEREO | IMPACT |  |  |  |  |  |
| 24 | 2.1.2.2.1.1 | Fabricate STE FM 1 Box |  | 15d | 2003-09-08 | 2003-09-26 | 15 |  |  | 2003-02-03 | 2003-03-24 | 35d | 33d |  | start no earlier than 2003-09-08 | STEREO | IMPACT |  |  |  |  |  |
| 25 | 3.1.3.2.3.1 | Fabricate STE FM 2 Detector Printed Wiring Board |  | 13d | 2003-08-29 A | 2003-09-17 | 15 | 8% | 12d | 2003-02-03 | 2003-02-12 | 8d | 1d |  | start no earlier than 2003-08-29 | STEREO | IMPACT |  |  |  |  |  |
| 26 | 3.1.3.2.2.2 | Fabrication STE FM 1 Detector Printed Wiring Board |  | 13d | 2003-08-29 A | 2003-09-17 | 15 | 8% | 12d | 2003-02-03 | 2003-02-12 | 8d | 1d |  | start no earlier than 2003-08-29 | STEREO | IMPACT |  |  |  |  |  |
| 27 | 3.1.3.2.2.2 | Fabricate LET FM 2 Internal Parts |  | 19d | 2003-10-16 | 2003-11-12 | 15 |  |  | 2003-02-03 | 2003-02-28 | 19d | 85d |  | start no earlier than 2003-04-30 | STEREO | IMPACT |  |  |  |  |  |
| 28 | 3.1.3.2.1.3 | Fabricate LET FM 1 Internal Parts |  | 19d | 2003-10-16 | 2003-11-12 | 15 |  |  | 2003-02-03 | 2003-02-28 | 19d | 72d |  | start no earlier than 2003-04-30 | STEREO | IMPACT |  |  |  |  |  |
| 29 | 3.1.2.1.2.1 | Fabricate SIT FM 2 Electronics Enclosure |  | 19d | 2003-07-16 | 2003-08-12 | 15 |  |  | 2003-02-18 | 2003-03-17 | 19d | 63.5d | 0d | start no earlier than 2003-05-31 | STEREO | IMPACT |  |  |  |  |  |
| 30 | 3.1.2.1.1.1 | Fabricate SIT FM 1 Electronics Enclosure |  | 19d | 2003-07-16 | 2003-08-12 | 15 |  |  | 2003-02-18 | 2003-03-17 | 19d | 18.5d | 0d | start no earlier than 2003-05-31 | STEREO | IMPACT |  |  |  |  |  |
| 31 | 3.1.2.1.2.3 | Fabricate SIT FM 2 Doors |  | 19d | 2003-09-09 | 2003-10-07 | 15 |  |  | 2003-02-18 | 2003-03-17 | 19d | 107.5d |  | start no earlier than 2003-05-31 | STEREO | IMPACT |  |  |  |  |  |
| 32 | 3.1.2.1.2.2 | Fabricate SIT FM 2 Housing |  | 19d | 2003-07-16 | 2003-08-12 | 15 |  |  | 2003-02-10 | 2003-03-10 | 19d | 63.5d | 0d | start no earlier than 2003-05-31 | STEREO | IMPACT |  |  |  |  |  |
| 33 | 3.1.2.1.1.4 | Fabricate SIT FM 1 Doors |  | 19d | 2003-09-09 | 2003-10-07 | 15 |  |  | 2003-02-18 | 2003-03-17 | 19d | 107.5d |  | start no earlier than 2003-05-31 | STEREO | IMPACT |  |  |  |  |  |
| 34 | 3.1.2.1.1.3 | Fabricate SIT FM 1 Housing |  | 19d | 2003-07-16 | 2003-08-12 | 15 |  |  | 2003-02-10 | 2003-03-10 | 19d | 18.5d | 0d | start no earlier than 2003-05-31 | STEREO | IMPACT |  |  |  |  |  |
| 35 | 7.1.3.2.2.1 | Fabricate SEPT-NS FM 2 N-S Brackets |  | 31d | 2003-08-06 | 2003-09-18 | 15 |  |  | 2003-03-05 | 2003-04-16 | 31d | 56d | 0d | start no earlier than 2003-04-30 | STEREO | IMPACT |  |  |  |  |  |
| 36 | 7.1.3.2.1.2 | Fabricate SEPT-NS FM 1 N-S Brackets |  | 31d | 2003-08-06 | 2003-09-18 | 15 |  |  | 2003-03-05 | 2003-04-16 | 31d | 56d | 0d | start no earlier than 2003-04-30 | STEREO | IMPACT |  |  |  |  |  |
| 37 | 8.1.2.2.2.1 | Fabricate STE-U FM 2 Shaper & Interface Printed Wiring Board |  | 10d | 2003-10-01 | 2003-10-15 | 15 |  |  | 2003-02-03 | 2003-02-14 | 10d | 37d | 0d | start no earlier than 2003-10-01 | STEREO | IMPACT |  |  |  |  |  |
| 38 | 8.1.2.2.1.1 | Fabricate STE-U FM 1Shaper & Interface Printed Wiring Board |  | 10d | 2003-10-01 | 2003-10-15 | 15 |  |  | 2003-02-03 | 2003-02-14 | 10d | 37d | 0d | start no earlier than 2003-10-01 | STEREO | IMPACT |  |  |  |  |  |
| 39 | 7.1.2.2.2.1 | Fabricate STE-U FM 2 Preamp Printed Wiring Board |  | 10d | 2003-09-10 | 2003-09-23 | 15 |  |  | 2003-07-01 | 2003-07-15 | 10d | 51d | 0d | start no earlier than 2003-09-10 | STEREO | IMPACT |  |  |  |  |  |
| 40 | 7.1.2.2.1.1 | Fabricate STE-U FM 1 Preamp Printed Wiring Board |  | 10d | 2003-09-10 | 2003-09-23 | 15 |  |  | 2003-07-01 | 2003-07-15 | 10d | 51d | 0d | start no earlier than 2003-09-10 | STEREO | IMPACT |  |  |  |  |  |
| 41 | 6.1.3.2.2.1 | Fabricate SWEA / STE-D FM 2 Digital to Analog Converter Printed Wiring Board |  | 10d | 2003-09-24 | 2003-10-08 | 15 |  |  | 2003-07-01 | 2003-07-15 | 10d | 26d | 0d | start no earlier than 2003-09-24 | STEREO | IMPACT |  |  |  |  |  |
| 42 | 6.1.3.2.1.1 | Fabricate SWEA / STE-D FM 1 Digital to Analog Converter Printed Wiring Board |  | 10d | 2003-09-24 | 2003-10-08 | 15 |  |  | 2003-07-01 | 2003-07-15 | 10d | 26d | 0d | start no earlier than 2003-09-24 | STEREO | IMPACT |  |  |  |  |  |
| 43 | 3.1.2.1.2.1 | Fabricate SWEA FM 2 Baseplate |  | 50d | 2003-07-01 A | 2003-09-10 | 15 | 86% | 7d | 2003-02-03 | 2003-02-24 | 15d | 95d | 39d | start no earlier than 2003-07-01 | STEREO | IMPACT |  |  |  |  |  |
| 44 | 3.1.2.1.1.1 | Fabricate SWEA FM 1 Baseplate |  | 50d | 2003-07-01 A | 2003-09-10 | 15 | 86% | 7d | 2003-02-03 | 2003-02-20 | 13d | 65d | 39d | start no earlier than 2003-07-01 | STEREO | IMPACT |  |  |  |  |  |
| 45 | 6.1.2.1.1 | Fabricate STE-D FM 2 Shaper Printed Wiring Board |  | 10d | 2003-09-17 | 2003-09-30 | 15 |  |  | 2003-07-01 | 2003-07-15 | 10d | 32d | 0d | start no earlier than 2003-09-17 | STEREO | IMPACT |  |  |  |  |  |
| 46 | 6.1.2.1.1 | Fabricate STE-D FM 1 Shaper Printed Wiring Board |  | 10d | 2003-09-17 | 2003-09-30 | 15 |  |  | 2003-07-01 | 2003-07-15 | 10d | 32d | 0d | start no earlier than 2003-09-17 | STEREO | IMPACT |  |  |  |  |  |
| 47 | 4.2.2.2.2.1 | Fabricate STE-D FM 2 Preamp Printed Wiring Board |  | 9d | 2003-09-10 | 2003-09-22 | 15 |  |  | 2003-07-01 | 2003-07-14 | 9d | 37d | 0d | start no earlier than 2003-09-10 | STEREO | IMPACT |  |  |  |  |  |
| 48 | 4.2.2.2.1.2 | Fabricate STE-D FM 1 Preamp Printed Wiring Board |  | 9d | 2003-09-10 | 2003-09-22 | 15 |  |  | 2003-07-01 | 2003-07-14 | 9d | 37d | 0d | start no earlier than 2003-09-10 | STEREO | IMPACT |  |  |  |  |  |
| 49 | 2.3.2.2.1 | SWEA FM 2 Mechanical Fabrication |  | 36d | 2002-12-02 A | 2003-01-31 A | 15FS+4d | 100% |  | 2002-12-02 | 2003-01-31 | 36d |  |  |  | STEREO | IMPACT |  |  |  |  |  |
| 50 | 2.3.2.1.2 | SWEA FM 1 Mechanical Fabrication |  | 36d | 2002-12-02 A | 2003-01-31 A | 15FS+4d | 100% |  | 2002-12-02 | 2003-01-31 | 36d |  |  |  | STEREO | IMPACT |  |  |  |  |  |
| 51 | 5.1.1.2.2 | Finalize HET Electronics Board Design |  | 13d | 2003-07-01 A | 2003-07-18 A | 15 | 100% |  | 2003-05-14 | 2003-05-28 | 10d |  |  | start no earlier than 2003-06-30 | STEREO | IMPACT |  |  |  |  |  |
| 52 | 3.1.1.1.1 | Place Order for LET FM 1, LET FM 2, LET Spare Housing |  | 2d | 2003-09-19 | 2003-09-22 | 15 |  |  | 2003-02-24 | 2003-02-25 | 2d | 54d |  | start no earlier than 2003-04-30 | STEREO | IMPACT |  |  |  |  |  |
| 53 | 3.1.3.2.3.1 | Receive and Inspect LET Spare Housing |  | 4d | 2003-10-10 | 2003-10-15 | 15 |  |  | 2003-03-14 | 2003-03-19 | 4d | 284d |  | start no earlier than 2003-04-30 | STEREO | IMPACT |  |  |  |  |  |
| 54 | 3.1.3.2.2.1 | Receive and Inspect LET FM 2 Housing |  | 4d | 2003-10-10 | 2003-10-15 | 15 |  |  | 2003-03-14 | 2003-03-19 | 4d | 67d |  | start no earlier than 2003-04-30 | STEREO | IMPACT |  |  |  |  |  |
| 55 | 3.1.3.2.1.2 | Receive & Inspect LET FM 1 Housing |  | 4d | 2003-10-10 | 2003-10-15 | 15 |  |  | 2003-03-14 | 2003-03-19 | 4d | 54d |  | start no earlier than 2003-04-30 | STEREO | IMPACT |  |  |  |  |  |
| 56 | 1.1.2.6 | Receive RFAs From Instrument CDR | milestone | 0d | 2003-05-31 A | 2003-05-31 A | 15FS+10d | 100% |  | 2002-12-09 | 2002-12-09 | 0d |  |  | start no earlier than 2003-05-31 | STEREO | IMPACT |  |  |  |  |  |
| 57 | 1.1.55 | Instrument PER | milestone | 0d | 2003-11-13 | 2003-11-13 |  |  |  | 2003-08-25 | 2003-08-25 | 0d | 407.76d |  | start no earlier than 2003-11-13 | STEREO | IMPACT | UC-B | PER |  | IMPACT - Instrument PER |  |
| 58 | 1.1.56 | IMPACT Suite FM 1 EMC Testing Complete | milestone | 0d | 2004-05-28 | 2004-05-28 | 99 |  |  | 2004-05-07 | 2004-05-07 | 0d | 270.76d |  |  | STEREO | IMPACT |  |  |  | IMPACT - Suite FM 1 EMC Testing Complete |  |
| 59 | 1.1.57 | SEP Package FM 2 EMC Testing Complete | milestone | 0d | 2004-06-07 | 2004-06-07 | 101 |  |  | 2004-05-14 | 2004-05-14 | 0d | 265.76d |  |  | STEREO | IMPACT |  |  |  | SEP Package - FM 2 EMC Testing Complete |  |
| 60 | 1.1.58 | Boom Suite FM 2 EMC Testing Complete | milestone | 0d | 2004-06-09 | 2004-06-09 | 102 |  |  | 2004-06-15 | 2004-06-15 | 0d | 263.76d |  |  | STEREO | IMPACT |  |  |  | Boom Suite - FM 2 EMC Testing Complete |  |
| 61 | 3.4.3.1 | FM 2 MAG Analog Board Build |  | 10d | 2003-10-27 | 2003-11-11 | 15 |  |  | 2003-05-28 | 2003-06-24 | 20d | 0d |  |  | STEREO | IMPACT |  |  |  |  |  |
| 62 | 3.4.2.1 | FM 1 MAG Analog Board Build |  | 10d | 2003-10-13 | 2003-10-27 | 15 |  |  | 2003-04-03 | 2003-04-29 | 19d | 0d |  |  | STEREO | IMPACT |  |  |  |  |  |
| 63 | 3.3.2.2.2 | FM 2 MAG PWB Fabrication |  | 27d | 2003-04-14 A | 2003-09-26 | 15 | 3% | 26.2d | 2003-03-03 | 2003-03-12 | 8d | 10d | 0d | start no earlier than 2003-03-31 | STEREO | IMPACT |  |  |  |  |  |
| 64 | 3.3.2.1.3 | FM 1 MAG PWB Fabrication |  | 27d | 2003-04-14 A | 2003-09-26 | 15 | 3% | 26.2d | 2003-03-03 | 2003-03-12 | 8d | 0d |  |  | STEREO | IMPACT |  |  |  |  |  |
| 65 | 3.3.2.2.1 | FM 2 MAG Sensor Build |  | 35d | 2003-04-01 A | 2003-05-19 A | 15 | 100% |  | 2003-02-03 | 2003-03-24 | 35d |  |  | start no earlier than 2003-03-31 | STEREO | IMPACT |  |  |  |  |  |
| 66 | 3.3.2.1.2 | FM 1 MAG Sensor Build |  | 35d | 2003-04-01 A | 2003-05-19 A | 15 | 100% |  | 2003-02-03 | 2003-03-24 | 35d |  |  | start no earlier than 2003-03-31 | STEREO | IMPACT |  |  |  |  |  |

Notes:
- 15: Removed activity 367 as predesessor need to watch this activity it drove CDR negative -0.15 days for 7/31 status. / Removed 4 days of slack for BOOM CDR Preparation as well as reducing duration for some of the BOOM CDR Preperation activities predecessors to hold date. / Removed BOOM CDR Prep -21.5d (8/31/02) status / Removed SIT 120 -17d (8/31/02) status driven by frontendlogic

| ID | WBS | Task | Type | Duration | Start | Finish | Predecessors | Complete | Remaining | Baseline start | Baseline finish | Baseline duration | Total slack | Free slack | Text11 | Text12 | Text28 | Text13 | Text22 | Text18 |
| --- | --- | --- | --- | --- | --- | --- | --- | --- | --- | --- | --- | --- | --- | --- | --- | --- | --- | --- | --- | --- |
| 67 | 1.1.65 | **Receivables** |  | 21d | 2004-05-03 | 2004-06-02 |  |  |  | 2004-04-08 | 2004-06-08 | 42d | 19d |  | STEREO | IMPACT | UC-B |  |  |  |
| 68 | 1.2.6.2.3 | Deliver BOOM Suite FM 1 For EMC Testing | milestone | 0d | 2004-05-13 | 2004-05-13 |  |  |  | 2004-04-01 | 2004-04-01 | 0d | 10d | 0d | STEREO | IMPACT |  |  |  |  |
| 69 | 1.1.65.2 | Receive BOOM Suite FM 1 For EMC Testing | milestone | 0d | 2004-05-14 | 2004-05-14 | 68FS+1d |  |  | 2004-04-08 | 2004-04-08 | 0d | 10d | 0d | STEREO | IMPACT | UC-B | Boom Suite |  |  |
| 70 | 1.2.6.3.3 | Deliver BOOM Suite FM 2 For EMC Testing | milestone | 0d | 2004-06-02 | 2004-06-02 |  |  |  | 2004-06-02 | 2004-06-02 | 0d | 8d | 0d | STEREO | IMPACT |  |  |  |  |
| 71 | 1.1.65.4 | Receive BOOM Suite FM 2 For EMC Testing | milestone | 0d | 2004-06-02 | 2004-06-02 | 70 |  |  | 2004-06-08 | 2004-06-08 | 0d | 8d | 0d | STEREO | IMPACT | UC-B | Boom Suite |  |  |
| 72 | 1.2.8.5 | Deliver SEP FM 1 to UC-B for EMC Testing | milestone | 0d | 2004-04-30 | 2004-04-30 |  |  |  | 2004-04-16 | 2004-04-16 | 0d | 19d | 0d | STEREO | IMPACT |  |  |  |  |
| 73 | 1.1.65.6 | Receive SEP Package FM 1 For EMC Testing | milestone | 0d | 2004-05-03 | 2004-05-03 | 72FS+1d |  |  | 2004-04-23 | 2004-04-23 | 0d | 19d | 9d | STEREO | IMPACT | UC-B | Boom Suite |  |  |
| 74 | 1.2.8.7 | Deliver SEP FM 2 to UC-B for EMC Testing | milestone | 0d | 2004-05-21 | 2004-05-21 |  |  |  | 2004-04-16 | 2004-04-16 | 0d | 158d | 0d | STEREO | IMPACT |  |  |  |  |
| 75 | 1.1.65.8 | Receive SEP Package FM 2 For EMC Testing | milestone | 0d | 2004-05-21 | 2004-05-21 | 74 |  |  | 2004-04-16 | 2004-04-16 | 0d | 158d | 5d | STEREO | IMPACT | UC-B | Boom Suite |  |  |
| 76 | 1.1.66 | **Deliverables** |  | 337d | 2003-02-07 A | 2004-06-09 |  |  | 337d | 2003-02-07 | 2004-06-15 | 340d | 151d |  | STEREO | IMPACT | UC-B |  |  |  |
| 77 | 1.1.66.1 | Deliver BOOM Suite FM 1 After EMC Testing | milestone | 0d | 2004-05-28 | 2004-05-28 | 99 |  |  | 2004-05-07 | 2004-05-07 | 0d | 12d | 0d | STEREO | IMPACT | UC-B | Boom Suite |  |  |
| 78 | 1.2.5.2.14 | Receive BOOM Suite FM 1 From IMPACT Suite EMC Testing | milestone | 0d | 2004-06-07 | 2004-06-07 | 77FS+5d |  |  | 2004-05-14 | 2004-05-14 | 0d | 12d | 0d | STEREO | IMPACT |  |  |  |  |
| 79 | 1.1.66.3 | Deliver BOOM Suite FM 2 After EMC Testing | milestone | 0d | 2004-06-09 | 2004-06-09 | 102 |  |  | 2004-06-15 | 2004-06-15 | 0d | 8d | 0d | STEREO | IMPACT | UC-B | Boom Suite | Deliver BOOM Suite FM 2 After EMC Testing |  |
| 80 | 1.2.5.3.10 | Receive BOOM Suite FM 2 From IMPACT Suite EMC Testing | milestone | 0d | 2004-06-16 | 2004-06-16 | 79FS+5d |  |  | 2004-06-16 | 2004-06-16 | 0d | 8d | 0d | STEREO | IMPACT |  |  |  |  |
| 81 | 1.1.66.5 | Deliver SEP Package FM 1 After EMC Testing | milestone | 0d | 2004-05-28 | 2004-05-28 | 99 |  |  | 2004-05-07 | 2004-05-07 | 0d | 158d | 0d | STEREO | IMPACT |  |  | Deliver SEP Package FM 1 After EMC Testing |  |
| 82 | 1.2.7.2 | Receive SEP Package FM 1 From IMPACT Suite EMC Testing | milestone | 0d | 2004-06-07 | 2004-06-07 | 81FS+5d |  |  | 2004-05-14 | 2004-05-14 | 0d | 158d |  | STEREO | IMPACT |  |  |  |  |
| 83 | 1.1.66.7 | Deliver SEP Package FM 2 After EMC Testing | milestone | 0d | 2004-06-07 | 2004-06-07 | 101 |  |  | 2004-05-14 | 2004-05-14 | 0d | 153d | 0d | STEREO | IMPACT |  |  | Deliver SEP Package FM 2 After EMC Testing |  |
| 84 | 1.2.7.4 | Receive SEP Package FM 2 From IMPACT Suite EMC Testing | milestone | 0d | 2004-06-14 | 2004-06-14 | 83FS+5d |  |  | 2004-05-21 | 2004-05-21 | 0d | 153d |  | STEREO | IMPACT |  |  |  |  |
| 85 | 1.1.66.9 | Deliver Flight ACTELs for HET | milestone | 0d | 2003-02-07 A | 2003-02-07 A | 95 | 100% |  | 2003-02-07 | 2003-02-07 | 0d |  |  | STEREO | IMPACT | GSFC |  |  | ACTEL |
| 86 | 1.1.66.10 | Deliver Flight ACTELS for SIT | milestone | 0d | 2003-02-07 A | 2003-02-07 A | 95 | 100% |  | 2003-02-07 | 2003-02-07 | 0d |  |  | STEREO | IMPACT | GSFC |  |  | ACTEL |
| 87 | 1.1.66.11 | Deliver Flight ACTELS for LET | milestone | 0d | 2003-02-07 A | 2003-02-07 A | 95 | 100% |  | 2003-02-07 | 2003-02-07 | 0d |  |  | STEREO | IMPACT | GSFC |  |  | ACTEL |
| 88 | 1.1.66.12 | Deliver Flight ACTELS for SEP Central | milestone | 0d | 2003-02-07 A | 2003-02-07 A | 95 | 100% |  | 2003-02-07 | 2003-02-07 | 0d |  |  | STEREO | IMPACT | GSFC |  |  | ACTEL |
| 89 | 1.1.66.13 | Deliver Flight ACTELS for S/WAVES | milestone | 0d | 2003-02-07 A | 2003-02-07 A | 95 | 100% |  | 2003-02-07 | 2003-02-07 | 0d |  |  | STEREO | IMPACT | GSFC |  |  | ACTEL |
| 90 | 1.1.66.14 | Deliver Flight ACTELS for PLASTIC | milestone | 0d | 2003-02-07 A | 2003-02-07 A | 95 | 100% |  | 2003-02-07 | 2003-02-07 | 0d |  |  | STEREO | IMPACT | GSFC |  |  | ACTEL |

| ID | WBS | Task | Type | Duration | Start | Finish | Predecessors | Complete | Remaining | Baseline start | Baseline finish | Baseline duration | Total slack | Free slack | Constraint | Work | Actual work | Text11 | Text12 | Text28 | Text22 | Text23 | Text20 | Text21 | Text13 | Text14 |
| --- | --- | --- | --- | --- | --- | --- | --- | --- | --- | --- | --- | --- | --- | --- | --- | --- | --- | --- | --- | --- | --- | --- | --- | --- | --- | --- |
| 91 | 1.2 | **Flight ACTELs** |  | 108d | 2002-09-03 A | 2003-02-07 A |  | 100% |  | 2002-09-03 | 2003-02-07 | 108d |  |  |  |  |  | STEREO | IMPACT | GSFC |  |  |  |  |  |  |
| 92 | 1.2.1 | Order ACTELS |  | 3d | 2002-09-03 A | 2002-09-05 A |  | 100% |  | 2002-09-03 | 2002-09-05 | 3d |  |  | start no earlier than 2002-09-30 |  |  | STEREO | IMPACT | GSFC |  |  |  |  |  |  |
| 93 | 1.2.2 | Receive Flight ACTELs | milestone | 1d | 2003-01-20 A | 2003-01-20 A | 92FS+90d | 100% |  | 2003-01-20 | 2003-01-20 | 1d |  |  |  |  |  | STEREO | IMPACT | GSFC | IMPACT - Flight ACTEL Lot Buy Received | IMPACT - Flight ACTEL Lot Buy Received |  |  |  |  |
| 94 | 1.2.3 | Inspect Flight ACTELs |  | 1d | 2003-01-21 A | 2003-01-21 A | 93 | 100% |  | 2003-01-21 | 2003-01-21 | 1d |  |  |  |  |  | STEREO | IMPACT |  |  |  |  |  |  |  |
| 95 | 1.2.4 | DPA Flight ACTELs |  | 13d | 2003-01-22 A | 2003-02-07 A | 94 | 100% |  | 2003-01-22 | 2003-02-07 | 13d |  |  |  |  |  | STEREO | IMPACT |  | IMPACT - Flight ACTEL Lot DPA Complete | IMPACT - Flight ACTEL Lot DPA Complete |  |  |  |  |
| 96 | 2 | **Integration & Test** |  | 17d | 2004-05-17 | 2004-06-09 |  |  |  | 2004-04-26 | 2004-06-15 | 36d | 10d |  |  |  |  | STEREO | IMPACT | UC-B |  |  |  |  |  |  |
| 97 | 2.1 | **FM 1** |  | 17d | 2004-05-17 | 2004-06-09 |  |  |  | 2004-04-26 | 2004-06-15 | 36d | 10d |  |  |  |  | STEREO | IMPACT | UC-B |  |  |  |  |  |  |
| 98 | 2.1.1 | **Suite** |  | 10d | 2004-05-17 | 2004-05-28 |  |  |  | 2004-04-26 | 2004-05-07 | 10d | 10d |  |  |  |  | STEREO | IMPACT | UC-B |  |  |  |  |  |  |
| 99 | 2.1.1.1 | IMPACT Suite FM 1 EMC Testing |  | 10d | 2004-05-17 | 2004-05-28 | 69, 73 |  |  | 2004-04-26 | 2004-05-07 | 10d | 10d | 0d |  |  |  | STEREO | IMPACT | UC-B |  |  | EMC | EMC |  |  |
| 100 | 2.1.2 | **FM 2** |  | 7d | 2004-06-01 | 2004-06-09 |  |  |  | 2004-05-10 | 2004-06-15 | 26d | 10d |  |  |  |  | STEREO | IMPACT |  |  |  |  |  |  |  |
| 101 | 2.1.2.1 | SEP Package FM 2 EMC Testing |  | 5d | 2004-06-01 | 2004-06-07 | 75, 99 |  |  | 2004-05-10 | 2004-05-14 | 5d | 153d | 0d |  |  |  | STEREO | IMPACT |  |  |  |  |  | Boom Suite |  |
| 102 | 2.1.2.2 | Boom Suite FM 2 EMC Testing |  | 5d | 2004-06-03 | 2004-06-09 | 71, 99 |  |  | 2004-06-09 | 2004-06-15 | 5d | 8d | 0d |  |  |  | STEREO | IMPACT |  |  |  |  |  | SEP Package |  |
| 103 | 3 | IMPACT Data Processing Unit |  | 1026d | 2000-06-09 A | 2004-07-12 |  | 82% | 184.74d | 2000-01-01 | 2004-06-04 | 1112d | 241.76d |  |  |  |  | STEREO | IMPACT |  |  |  |  |  |  |  |
| 104 | 4 | IMPACT Power Converters |  | 904d | 2000-07-31 A | 2004-03-09 |  | 66% | 309.9d | 2000-07-31 | 2004-01-09 | 864d | 328.76d |  |  |  |  | STEREO | IMPACT |  |  |  |  |  |  | PS |
| 105 | 5 | IMPACT BOOM |  | 1080d | 2000-05-26 A | 2004-09-14 |  | 71% | 315.86d | 2000-01-03 | 2004-09-15 | 1183d | 196.76d |  |  |  |  | STEREO | IMPACT | UC-B |  |  |  |  | Boom Suite |  |
| 106 | 6 | IMPACT SEP |  | 1207.76d? | 2000-09-05 A | 2005-06-28 |  | 59% | 490.19d? | 2000-09-05 | 2005-09-16 | 1264d? | 0d |  |  | 8409.6h | 8277.6h | STEREO | IMPACT | CIT |  |  |  |  |  |  |
