# LET - Low Energy Telescope

Schedule from MS Project, 2000-09-05 to 2004-12-02, status date 2003-08-31, A marks actual dates.
LET Instrument Development Schedule
NASA GSFC
Status Date: 08/31/2003 / Baseline Date: 01/31/2003 R1

## Calendars

- Standard w/ 10 Gov't Holidays: Mon-Fri 08:00-12:00, 13:00-17:00; Sat-Sun off. Exceptions (off unless hours are given): 2000-10-09, 2000-11-13, 2000-11-23, 2000-12-25, 2001-01-01, 2001-01-15, 2001-02-19, 2001-05-28, 2001-07-04, 2001-09-03, 2001-10-08, 2001-11-12, 2001-11-22, 2001-12-25, 2002-01-01, 2002-01-14, 2002-02-18, 2002-05-27, 2002-07-04, 2002-09-02, 2002-10-07, 2002-11-11, 2002-11-28, 2002-12-25, 2003-01-01, 2003-01-13, 2003-02-17, 2003-05-26, 2003-07-04, 2003-09-01, 2003-10-06, 2003-11-10, 2003-11-27, 2003-12-25, 2004-01-01, 2004-01-12, 2004-02-16, 2004-05-31, 2004-07-05, 2004-09-06, 2004-10-11, 2004-11-08, 2004-11-25.

## Resources

| Resource |
| --- |
| Kecman |
| Burnham |
| Nguyen |
| Wiedenbeck |
| Geier |

## Schedule

| ID | WBS | Task | Type | Duration | Start | Finish | Predecessors | Complete | Remaining | Baseline start | Baseline finish | Baseline duration | Total slack | Free slack | Constraint | Text11 | Text12 | Text13 | Text14 | Text16 | Text28 | Text22 | Text23 | Text17 | Text20 | Text21 |
| --- | --- | --- | --- | --- | --- | --- | --- | --- | --- | --- | --- | --- | --- | --- | --- | --- | --- | --- | --- | --- | --- | --- | --- | --- | --- | --- |
| 1 | 1 | **Management** |  | 669d | 2001-06-27 A | 2004-02-27 |  | 60% | 267.6d | 2001-06-27 | 2004-02-27 | 669d | 193d |  |  | STEREO | IMPACT | SEP Package | LET | LET | CIT |  |  |  |  |  |
| 2 | 1.1 | **Contingency** |  | 1d | 2004-02-27 | 2004-02-27 |  |  |  | 2004-02-27 | 2004-02-27 | 1d | 1d |  |  | STEREO | IMPACT | SEP Package | LET | LET | CIT |  |  |  |  |  |
| 3 | 1.1.1 | LET FM 1 Delivery to CIT For SEP I & T Contingency |  | 1d | 2004-02-27 | 2004-02-27 | 363, 10 |  |  | 2004-02-27 | 2004-02-27 | 1d | 1d | 0d |  | STEREO | IMPACT | SEP Package | LET | LET | CIT |  |  |  |  |  |
| 4 | 1.1.2 | LET FM 2 Delivery to CIT For SEP I & T Contingency |  | 1d | 2004-02-27 | 2004-02-27 | 372, 371, 11 |  |  | 2004-02-27 | 2004-02-27 | 1d | 14d | 0d |  | STEREO | IMPACT | SEP Package | LET | LET | CIT |  |  |  |  |  |
| 5 | 1.2 | **Milestones** |  | 669d | 2001-06-27 A | 2004-02-27 |  | 99% | 0d | 2001-06-27 | 2004-02-27 | 669d | 193d |  |  | STEREO | IMPACT | SEP Package | LET | LET | CIT |  |  |  |  |  |
| 6 | 1.2.1 | LET L1 Detector Decision |  | 1d | 2003-01-31 A | 2003-01-31 A |  | 100% |  | 2003-01-31 | 2003-01-31 | 1d |  |  | start no earlier than 2003-02-01 | STEREO | IMPACT | SEP Package | LET | LET | CIT | LET - L1 Detector Decision Trigger Event | L1 Detector Decision |  |  |  |
| 7 | 1.2.2 | LET Software Requirements Review | milestone | 0d | 2002-05-21 A | 2002-05-21 A |  | 100% |  | 2002-05-21 | 2002-05-21 | 0d |  |  | finish no earlier than 2002-04-30 | STEREO | IMPACT | SEP Package | LET | LET | CIT |  |  |  |  |  |
| 8 | 1.2.3 | **Receivables** |  | 532d | 2002-01-15 A | 2004-02-26 |  | 99% | 0d | 2002-01-15 | 2004-02-26 | 532d | 194d |  |  | STEREO | IMPACT | SEP Package | LET | LET | CIT |  |  |  |  |  |
| 9 | 1.2.3.1 | Receive LET Spare Housing | milestone | 0d | 2003-10-15 | 2003-10-15 | 59 |  |  | 2003-10-15 | 2003-10-15 | 0d | 284d | 0d | start no earlier than 2003-06-30 | STEREO | IMPACT | SEP Package | LET | LET | CIT |  |  |  |  |  |
| 10 | 1.2.3.2 | Receive LET FM 1 Brackets With Integrated Housing & Detectors from GSFC | milestone | 0d | 2004-02-26 | 2004-02-26 | 16, 384 |  |  | 2004-02-26 | 2004-02-26 | 0d | 1d | 0d |  | STEREO | IMPACT | SEP Package | LET | LET | CIT |  |  |  |  |  |
| 11 | 1.2.3.3 | Receive LET FM 2 Brackets With Integrated Housing & Detectors from GSFC | milestone | 0d | 2004-02-26 | 2004-02-26 | 17, 386 |  |  | 2004-02-26 | 2004-02-26 | 0d | 14d | 0d |  | STEREO | IMPACT | SEP Package | LET | LET | CIT |  |  |  |  |  |
| 12 | 1.1.8.8 | Deliver Software Requirements Doc To LET |  | 1d | 2002-01-15 A | 2002-01-15 A |  | 100% |  | 2002-01-15 | 2002-01-15 | 1d |  |  |  | STEREO | IMPACT | SEP Package | LET | LET | CIT |  |  |  |  |  |
| 13 | 1.2.3.5 | Receive Software Requirements Doc |  | 1d | 2002-01-15 A | 2002-01-15 A | 12 | 100% |  | 2002-01-15 | 2002-01-15 | 1d |  |  |  | STEREO | IMPACT | SEP Package | LET | LET | CIT |  |  |  |  |  |
| 14 | 1.2.3.6 | Receive LET EM Mockup from GSFC | milestone | 0d | 2003-04-30 A | 2003-04-30 A | 34 | 100% |  | 2003-04-30 | 2003-04-30 | 0d |  |  | start no earlier than 2003-04-30 | STEREO | IMPACT | SEP Package | LET | LET | CIT |  |  |  |  |  |
| 15 | 1.2.4 | **Deliverables** |  | 669d | 2001-06-27 A | 2004-02-27 |  | 99% | 0d | 2001-06-27 | 2004-02-27 | 669d | 193d |  |  | STEREO | IMPACT | SEP Package | LET | LET | CIT |  |  | HET |  |  |
| 16 | 1.2.4.1 | Deliver LET FM 1 Brackets With Integrated Housing & Detectors to CIT | milestone | 0d | 2003-11-12 | 2003-11-12 | 54 |  |  | 2003-11-12 | 2003-11-12 | 0d | 72d | 71d | start no earlier than 2003-04-30 | STEREO | IMPACT | SEP Package | LET | LET | GSFC |  |  |  |  |  |
| 17 | 1.2.4.2 | Deliver LET FM 2 Brackets With Integrated Housing & Detectors to CIT | milestone | 0d | 2003-11-12 | 2003-11-12 | 57 |  |  | 2003-11-12 | 2003-11-12 | 0d | 85d | 71d | start no earlier than 2003-04-30 | STEREO | IMPACT | SEP Package | LET | LET | GSFC |  |  |  |  |  |
| 18 | 1.2.4.3 | Deliver LET EM to I & T | milestone | 0d | 2003-10-15 | 2003-10-15 | 326, 24, 9 |  |  | 2003-10-15 | 2003-10-15 | 0d | 284d | 0d |  | STEREO | IMPACT | SEP Package | LET | LET | CIT | Deliver LET EM to I & T | EM Delivery For SEP Package EM I & T |  | LET EM |  |
| 19 | 1.2.7.7.6 | Receive LET EM for SEP EM I & T | milestone | 0d | 2003-10-22 | 2003-10-22 | 18FS+5d |  |  | 2003-10-22 | 2003-10-22 | 0d | 314d |  | start no earlier than 2003-07-15 | STEREO | IMPACT | SEP Package | LET | LET | CIT |  |  |  |  |  |
| 20 | 1.2.4.5 | Deliver LET FM 1 to CIT For SEP I & T | milestone | 0d | 2004-02-27 | 2004-02-27 | 3 |  |  | 2004-02-27 | 2004-02-27 | 0d | 1d | 0d |  | STEREO | IMPACT | SEP Package | LET | LET | CIT | LET - FM 1 Delivery to SEP I & T | FM1 Delivery for SEP Package I & T |  | LET FM 1 | LET FM1 & FM2 Avail |
| 21 | 1.2.7.7.8 | Receive LET FM 1 For SEP FM 1 I & T | milestone | 0d | 2004-03-05 | 2004-03-05 | 20FS+5d |  |  | 2004-03-05 | 2004-03-05 | 0d | 1d | 0d |  | STEREO | IMPACT | SEP Package | LET | LET | CIT |  |  |  |  |  |
| 22 | 1.2.4.7 | Deliver LET FM 2 to CIT For SEP I & T | milestone | 0d | 2004-02-27 | 2004-02-27 | 4 |  |  | 2004-02-27 | 2004-02-27 | 0d | 14d | 0d |  | STEREO | IMPACT | SEP Package | LET | LET | CIT | LET - FM 2 Delivery to SEP I & T | FM 2 Delivery for SEP Package I & T |  | LET FM 2 | LET FM1 & FM2 Avail |
| 23 | 1.2.7.7.10 | Receive LET FM 2 For SEP FM 2 I & T | milestone | 0d | 2004-03-05 | 2004-03-05 | 22FS+5d |  |  | 2004-03-05 | 2004-03-05 | 0d | 14d | 0d |  | STEREO | IMPACT | SEP Package | LET | LET | CIT |  |  |  |  |  |
| 24 | 1.2.4.9 | Deliver LET S/W Build 2 | milestone | 0d | 2003-07-31 A | 2003-07-31 A | 380 | 100% |  | 2003-07-31 | 2003-07-31 | 0d |  |  |  | STEREO | IMPACT | SEP Package | LET | LET | CIT |  |  |  |  |  |
| 25 | 1.2.7.7.2 | Receive LET S/W Build 2 | milestone | 0d | 2003-07-02 A | 2003-07-02 A | 24 | 100% |  | 2003-07-02 | 2003-07-02 | 0d |  |  |  | STEREO | IMPACT | SEP Package | LET | LET | CIT |  |  |  |  |  |
| 26 | 1.1.7.5.2 | Receive LET S/W Build 2 | milestone | 0d | 2003-07-31 A | 2003-07-31 A | 24 | 100% |  | 2003-07-31 | 2003-07-31 | 0d |  |  |  | STEREO | IMPACT | SEP Package | LET | LET | CIT |  |  |  |  |  |
| 27 | 1.2.4.12 | Deliver LET S/W Build 3 | milestone | 0d | 2003-11-03 | 2003-11-03 | 381 |  |  | 2003-11-03 | 2003-11-03 | 0d | 78d | 0d |  | STEREO | IMPACT | SEP Package | LET | LET | CIT |  |  |  |  |  |
| 28 | 1.2.7.7.4 | Receive LET S/W Build 3 | milestone | 0d | 2003-11-03 | 2003-11-03 | 27 |  |  | 2003-11-03 | 2003-11-03 | 0d | 84d | 83d |  | STEREO | IMPACT | SEP Package | LET | LET | CIT |  |  |  |  |  |
| 29 | 1.1.7.5.4 | Receive LET S/W Build 3 | milestone | 0d | 2003-11-03 | 2003-11-03 | 27 |  |  | 2003-11-03 | 2003-11-03 | 0d | 78d | 17d |  | STEREO | IMPACT | SEP Package | LET | LET | CIT |  |  |  |  |  |
| 30 | 1.2.4.15 | Deliver Sample Flight VLSI Chip to GSFC | milestone | 0d | 2002-05-01 A | 2002-05-01 A | 127 | 100% |  | 2002-05-01 | 2002-05-01 | 0d |  |  |  | STEREO | IMPACT | SEP Package | LET | LET | CIT |  |  |  |  |  |
| 31 | 1.1.5.2 | Receive PHA Chip From CIT | milestone | 0d | 2002-05-01 A | 2002-05-01 A | 30 | 100% |  | 2002-05-01 | 2002-05-01 | 0d |  |  |  | STEREO | IMPACT | SEP Package | LET | LET | CIT |  |  |  |  |  |
| 32 | 1.1.4.13 | Deliver VLSI Chip Definition to SIT and HET |  | 1d | 2001-06-27 A | 2001-06-27 A | 93 | 100% |  | 2001-06-27 | 2001-06-27 | 1d |  |  |  | STEREO | IMPACT | SEP Package | LET | LET | CIT |  |  |  |  | VLSI Chip Def to SIT & HET |
| 33 | 1.1.5.5 | Receive VLSI Chip Definition From CIT For SIT and HET | milestone | 0d | 2001-06-27 A | 2001-06-27 A | 32 | 100% |  | 2001-06-27 | 2001-06-27 | 0d |  |  |  | STEREO | IMPACT | SEP Package | LET | LET | CIT |  |  |  |  |  |
| 34 | 1.2.4.19 | Deliver LET EM Mechanical Mockup to CIT | milestone | 0d | 2003-04-30 A | 2003-04-30 A |  | 100% |  | 2003-04-30 | 2003-04-30 | 0d |  |  | start no earlier than 2003-04-30 | STEREO | IMPACT | SEP Package | LET | LET | CIT |  |  |  |  |  |

Notes:
- 3: Removed 12 days of duration 1/9/03
- 4: Removed 12 days of duration 1/9/03
- 20: FNL of 12/31/03 removed 1/9/03
- 22: FNL of 12/31/03 removed 1/9/03

| ID | WBS | Task | Type | Duration | Start | Finish | Predecessors | Complete | Remaining | Baseline start | Baseline finish | Baseline duration | Total slack | Free slack | Constraint | Text11 | Text12 | Text13 | Text14 | Text16 | Text28 | Text19 |
| --- | --- | --- | --- | --- | --- | --- | --- | --- | --- | --- | --- | --- | --- | --- | --- | --- | --- | --- | --- | --- | --- | --- |
| 35 | 2 | **Systems Engineering** |  | 680d | 2000-09-05 A | 2003-05-21 |  | 95% | 32.9d | 2000-09-05 | 2003-05-21 | 680d | 385d |  |  | STEREO | IMPACT | SEP Package | LET | LET | CIT |  |
| 36 | 2.1 | **Documentation** |  | 60d | 2001-08-13 A | 2001-11-06 A |  | 100% |  | 2001-08-13 | 2001-11-06 | 60d |  |  |  | STEREO | IMPACT | SEP Package | LET | LET | CIT |  |
| 37 | 2.1.1 | LET ICD Drawings |  | 60d | 2001-08-13 A | 2001-11-06 A | 39 | 100% |  | 2001-08-13 | 2001-11-06 | 60d |  |  |  | STEREO | IMPACT | SEP Package | LET | LET | CIT |  |
| 38 | 2.2 | **Studies** |  | 680d | 2000-09-05 A | 2003-05-21 |  | 94% | 40.8d | 2000-09-05 | 2003-05-21 | 680d | 385d |  |  | STEREO | IMPACT | SEP Package | LET | LET | CIT |  |
| 39 | 2.2.1 | Analyze Fields of View |  | 235d | 2000-09-05 A | 2001-08-10 A |  | 100% |  | 2000-09-05 | 2001-08-10 | 235d |  |  | start no earlier than 2000-09-05 | STEREO | IMPACT | SEP Package | LET | LET | GSFC |  |
| 40 | 2.2.2 | LET Vibration Analysis |  | 15d | 2003-05-01 | 2003-05-21 |  |  |  | 2003-05-01 | 2003-05-21 | 15d | 385d | 0d | start no earlier than 2003-04-30 | STEREO | IMPACT | SEP Package | LET | LET | GSFC |  |
| 41 | 3 | **Structure** |  | 386d | 2002-05-01 A | 2003-11-12 |  | 53% | 179.5d | 2002-05-01 | 2003-11-12 | 386d | 265d |  |  | STEREO | IMPACT | SEP Package | LET | LET | GSFC |  |
| 42 | 3.1 | **Design, Manufacture, Assembly and Test** |  | 386d | 2002-05-01 A | 2003-11-12 |  | 53% | 179.5d | 2002-05-01 | 2003-11-12 | 386d | 265d |  |  | STEREO | IMPACT | SEP Package | LET | LET | GSFC |  |
| 43 | 3.1.1 | **Procurements** |  | 2d | 2003-09-19 | 2003-09-22 |  |  |  | 2003-09-19 | 2003-09-22 | 2d | 54d |  |  | STEREO | IMPACT | SEP Package | LET | LET | GSFC |  |
| 44 | 3.1.1.1 | **FM 1 & FM 2** |  | 2d | 2003-09-19 | 2003-09-22 |  |  |  | 2003-09-19 | 2003-09-22 | 2d | 54d |  |  | STEREO | IMPACT | SEP Package | LET | LET | GSFC |  |
| 45 | 3.1.1.1.1 | Place Order for LET FM 1, LET FM 2, LET Spare Housing |  | 2d | 2003-09-19 | 2003-09-22 | 47, 52 |  |  | 2003-09-19 | 2003-09-22 | 2d | 54d | 0d | start no earlier than 2003-04-30 | STEREO | IMPACT | SEP Package | LET | LET | GSFC | Sandy Shuman |
| 46 | 3.1.2 | **Design** |  | 349d | 2002-05-01 A | 2003-09-18 |  | 85% | 52.35d | 2002-05-01 | 2003-09-18 | 349d | 54d |  |  | STEREO | IMPACT | SEP Package | LET | LET | GSFC |  |
| 47 | 3.1.2.1 | Design LET Housing |  | 90d | 2002-05-01 A | 2003-09-18 | 157, 156 | 85% | 13.5d | 2002-05-01 | 2003-09-18 | 90d | 54d | 0d | finish no earlier than 2003-02-21 | STEREO | IMPACT | SEP Package | LET | LET | GSFC | Sandy Shuman |
| 48 | 3.1.3 | **Fabrication** |  | 135d | 2003-05-01 | 2003-11-12 |  |  |  | 2003-05-01 | 2003-11-12 | 135d | 166d |  |  | STEREO | IMPACT | SEP Package | LET | LET | GSFC |  |
| 49 | 3.1.3.1 | ETU |  | 1d | 2003-05-01 | 2003-05-01 |  |  |  | 2003-05-01 | 2003-05-01 | 1d | 399d |  | start no earlier than 2003-04-30 | STEREO | IMPACT | SEP Package | LET | LET | CIT |  |
| 50 | 3.1.3.2 | **FM 1 & FM 2** |  | 23d | 2003-10-10 | 2003-11-12 |  |  |  | 2003-10-10 | 2003-11-12 | 23d | 54d |  |  | STEREO | IMPACT | SEP Package | LET | LET | GSFC |  |
| 51 | 3.1.3.2.1 | **FM 1** |  | 23d | 2003-10-10 | 2003-11-12 |  |  |  | 2003-10-10 | 2003-11-12 | 23d | 54d |  |  | STEREO | IMPACT | SEP Package | LET | LET | GSFC |  |
| 52 | 1.1.13 | Instrument CDR | milestone | 3d | 2002-11-20 A | 2002-11-22 A | 40FS-10d | 100% |  | 2002-11-20 | 2002-11-22 | 3d |  |  | finish no earlier than 2002-11-22 | STEREO | IMPACT | SEP Package | LET | LET | CIT |  |
| 53 | 3.1.3.2.1.2 | Receive & Inspect LET FM 1 Housing |  | 4d | 2003-10-10 | 2003-10-15 | 45FS+12d, 52 |  |  | 2003-10-10 | 2003-10-15 | 4d | 54d | 0d | start no earlier than 2003-04-30 | STEREO | IMPACT | SEP Package | LET | LET | GSFC | Sandy Shuman |
| 54 | 3.1.3.2.1.3 | Fabricate LET FM 1 Internal Parts |  | 19d | 2003-10-16 | 2003-11-12 | 52, 53 |  |  | 2003-10-16 | 2003-11-12 | 19d | 72d | 0d | start no earlier than 2003-04-30 | STEREO | IMPACT | SEP Package | LET | LET | GSFC | Sandy Shuman |
| 55 | 3.1.3.2.2 | **FM 2** |  | 23d | 2003-10-10 | 2003-11-12 |  |  |  | 2003-10-10 | 2003-11-12 | 23d | 67d |  |  | STEREO | IMPACT | SEP Package | LET | LET | GSFC |  |
| 56 | 3.1.3.2.2.1 | Receive and Inspect LET FM 2 Housing |  | 4d | 2003-10-10 | 2003-10-15 | 45FS+12d, 52 |  |  | 2003-10-10 | 2003-10-15 | 4d | 67d | 0d | start no earlier than 2003-04-30 | STEREO | IMPACT | SEP Package | LET | LET | GSFC | Sandy Shuman |
| 57 | 3.1.3.2.2.2 | Fabricate LET FM 2 Internal Parts |  | 19d | 2003-10-16 | 2003-11-12 | 52, 56 |  |  | 2003-10-16 | 2003-11-12 | 19d | 85d | 0d | start no earlier than 2003-04-30 | STEREO | IMPACT | SEP Package | LET | LET | GSFC | Sandy Shuman |
| 58 | 3.1.3.2.3 | **Spare** |  | 4d | 2003-10-10 | 2003-10-15 |  |  |  | 2003-10-10 | 2003-10-15 | 4d | 284d |  |  | STEREO | IMPACT | SEP Package | LET | LET | GSFC |  |
| 59 | 3.1.3.2.3.1 | Receive and Inspect LET Spare Housing |  | 4d | 2003-10-10 | 2003-10-15 | 45FS+12d, 52 |  |  | 2003-10-10 | 2003-10-15 | 4d | 284d | 0d | start no earlier than 2003-04-30 | STEREO | IMPACT | SEP Package | LET | LET | GSFC | Sandy Shuman |

Notes:
- 40: Modified CDR Successor fs-10d

| ID | WBS | Task | Duration | Start | Finish | Predecessors | Complete | Remaining | Baseline start | Baseline finish | Baseline duration | Total slack | Free slack | Constraint | Text11 | Text12 | Text13 | Text14 | Text16 | Text28 | Text29 | Text20 | Text21 |
| --- | --- | --- | --- | --- | --- | --- | --- | --- | --- | --- | --- | --- | --- | --- | --- | --- | --- | --- | --- | --- | --- | --- | --- |
| 60 | 4 | **Detector** | 945d | 2001-03-01 A | 2004-12-02 |  | 50% | 472.11d | 2001-03-01 | 2004-12-02 | 945d | 0d |  |  | STEREO | IMPACT | SEP Package | LET | LET | CIT |  |  |  |
| 61 | 4.1 | Detector oversight | 336d | 2003-08-01 A | 2004-12-02 |  | 6% | 315d | 2003-08-01 | 2004-12-02 | 336d | 0d |  | start no earlier than 2003-08-01 | STEREO | IMPACT | SEP Package | LET | LET | CIT | L1 Plan B |  |  |
| 62 | 4.2 | **Design, Manufacture, Assembly and Test** | 733d | 2001-03-01 A | 2004-01-30 |  | 40% | 436.37d | 2001-03-01 | 2004-01-30 | 733d | 5d |  |  | STEREO | IMPACT | SEP Package | LET | LET | CIT |  |  |  |
| 63 | 4.2.1 | Design detector | 108.2d | 2001-03-01 A | 2002-07-17 A |  | 100% |  | 2001-03-01 | 2002-07-17 | 108.2d |  |  | start no earlier than 2001-03-01 | STEREO | IMPACT | SEP Package | LET | LET | CIT |  |  |  |
| 64 | 4.2.2 | **Procure Detectors** | 610d | 2001-08-23 A | 2004-01-30 |  | 11% | 541.89d | 2001-08-23 | 2004-01-30 | 610d | 5d |  |  | STEREO | IMPACT | SEP Package | LET | LET | CIT |  |  |  |
| 65 | 4.2.2.1 | Order prototypes | 1d | 2001-08-23 A | 2001-08-23 A | 63FS+15d | 100% |  | 2001-08-23 | 2001-08-23 | 1d |  |  |  | STEREO | IMPACT | SEP Package | LET | LET | CIT |  |  |  |
| 66 | 4.2.2.2 | Order prototypes L1 plan B | 1d | 2001-12-17 A | 2001-12-17 A |  | 100% |  | 2001-12-17 | 2001-12-17 | 1d |  |  | start no earlier than 2001-12-17 | STEREO | IMPACT | SEP Package | LET | LET | CIT |  |  |  |
| 67 | 4.2.2.3 | Evaluate prototypes L1 plan B | 19d | 2002-12-02 A | 2002-12-27 A | 66FS+100d | 100% |  | 2002-12-02 | 2002-12-27 | 19d |  |  | start no earlier than 2002-11-30 | STEREO | IMPACT | SEP Package | LET | LET | CIT |  |  |  |
| 68 | 4.2.2.4 | Order flight Detectors | 2d | 2003-02-17 A | 2003-02-19 A | 67 | 100% |  | 2003-02-17 | 2003-02-19 | 2d |  |  | start no earlier than 2003-02-28 | STEREO | IMPACT | SEP Package | LET | LET | CIT |  | All Flt Detectors Ordered | All Flt Detectors Ordered |
| 69 | 4.2.2.5 | Flight L1 Detectors | 80d | 2003-09-02 | 2003-12-26 | 68 |  |  | 2003-09-02 | 2003-12-26 | 80d | 28d | 23d | start no earlier than 2003-09-02 | STEREO | IMPACT | SEP Package | LET | LET | CIT |  |  |  |
| 70 | 4.2.2.6 | Flight Detectors L2, L3, H | 103d | 2003-09-02 | 2004-01-30 | 68 |  |  | 2003-09-02 | 2004-01-30 | 103d | 5d | 0d | start no earlier than 2003-09-02 | STEREO | IMPACT | SEP Package | LET | LET | CIT |  |  |  |
| 71 | 4.2.3 | **Detector fixturing** | 398d | 2001-12-03 A | 2003-07-02 A |  | 100% |  | 2001-12-03 | 2003-07-02 | 398d |  |  |  | STEREO | IMPACT | SEP Package | LET | LET | CIT |  |  |  |
| 72 | 4.2.3.1 | Design Detector Fixturing | 10d | 2001-12-03 A | 2003-05-01 A |  | 100% |  | 2001-12-03 | 2003-05-01 | 10d |  |  | start no earlier than 2001-12-03 | STEREO | IMPACT | SEP Package | LET | LET | CIT |  |  |  |
| 73 | 4.2.3.2 | Clean & Assemble Detector Fixturing | 4d | 2003-05-08 A | 2003-07-02 A | 72FS+18d | 100% |  | 2003-05-08 | 2003-07-02 | 4d |  |  | start no earlier than 2003-02-01 | STEREO | IMPACT | SEP Package | LET | LET | CIT |  |  |  |
| 74 | 4.2.4 | **Test equip** | 692d | 2001-04-02 A | 2004-01-02 |  | 38% | 428.77d | 2001-04-02 | 2004-01-02 | 692d | 23d |  |  | STEREO | IMPACT | SEP Package | LET | LET | CIT |  |  |  |
| 75 | 4.2.4.1 | **Mechanical** | 564.65d | 2001-04-02 A | 2003-06-30 A |  | 100% |  | 2001-04-02 | 2003-06-30 | 564.65d |  |  |  | STEREO | IMPACT | SEP Package | LET | LET | CIT |  |  |  |
| 76 | 4.2.4.1.1 | Design Mechanical Test Equipment | 59d | 2001-04-02 A | 2003-05-05 A |  | 100% |  | 2001-04-02 | 2003-05-05 | 59d |  |  | start no earlier than 2001-04-02 | STEREO | IMPACT | SEP Package | LET | LET | CIT |  |  |  |
| 77 | 4.2.4.1.2 | Clean & Assemble Mechanical Test Equipment | 58d | 2001-07-23 A | 2003-06-05 A | 76FS+19d | 100% |  | 2001-07-23 | 2003-06-05 | 58d |  |  |  | STEREO | IMPACT | SEP Package | LET | LET | CIT |  |  |  |
| 78 | 4.2.4.1.3 | Test & Debug Mechanical Test Equipment | 56d | 2001-10-15 A | 2003-06-30 A | 77 | 100% |  | 2001-10-15 | 2003-06-30 | 56d |  |  |  | STEREO | IMPACT | SEP Package | LET | LET | CIT |  |  |  |
| 79 | 4.2.4.2 | **Electronics** | 24d | 2003-09-02 | 2003-10-03 |  |  |  | 2003-09-02 | 2003-10-03 | 24d | 83d |  |  | STEREO | IMPACT | SEP Package | LET | LET | CIT |  |  |  |
| 80 | 4.2.4.2.1 | Electronic Test Equipment Design | 1d | 2003-09-02 | 2003-09-02 |  |  |  | 2003-09-02 | 2003-09-02 | 1d | 83d | 0d | start no earlier than 2003-09-02 | STEREO | IMPACT | SEP Package | LET | LET | CIT |  |  |  |
| 81 | 4.2.4.2.2 | Electronic Test Equipment Layout | 2d | 2003-09-03 | 2003-09-04 | 80 |  |  | 2003-09-03 | 2003-09-04 | 2d | 83d | 0d |  | STEREO | IMPACT | SEP Package | LET | LET | CIT |  |  |  |
| 82 | 4.2.4.2.3 | Procure Electronic Test Equipment Labor | 1d | 2003-09-05 | 2003-09-05 | 81 |  |  | 2003-09-05 | 2003-09-05 | 1d | 83d | 0d |  | STEREO | IMPACT | SEP Package | LET | LET | CIT |  |  |  |
| 83 | 4.2.4.2.4 | Assemble Electronics Test Box | 5d | 2003-09-22 | 2003-09-26 | 82FS+10d |  |  | 2003-09-22 | 2003-09-26 | 5d | 83d | 0d |  | STEREO | IMPACT | SEP Package | LET | LET | CIT |  |  |  |
| 84 | 4.2.4.2.5 | Test & Debug Electronics Test Box | 5d | 2003-09-29 | 2003-10-03 | 83 |  |  | 2003-09-29 | 2003-10-03 | 5d | 83d | 0d |  | STEREO | IMPACT | SEP Package | LET | LET | CIT |  |  |  |

| ID | WBS | Task | Type | Duration | Start | Finish | Predecessors | Complete | Remaining | Baseline start | Baseline finish | Baseline duration | Total slack | Free slack | Constraint | Text11 | Text12 | Text13 | Text14 | Text16 | Text28 |
| --- | --- | --- | --- | --- | --- | --- | --- | --- | --- | --- | --- | --- | --- | --- | --- | --- | --- | --- | --- | --- | --- |
| 85 | 4.2.4.3 | **Test detectors** |  | 105d | 2003-08-01 A | 2004-01-02 |  | 7% | 98.17d | 2003-08-01 | 2004-01-02 | 105d | 1d |  |  | STEREO | IMPACT | SEP Package | LET | LET | CIT |
| 86 | 4.2.4.3.1 | Perform EM Testing |  | 21d | 2003-08-01 A | 2003-08-29 A |  | 100% |  | 2003-08-01 | 2003-09-25 | 39d |  |  | start no earlier than 2003-08-01 | STEREO | IMPACT | SEP Package | LET | LET | CIT |
| 87 | 4.2.4.3.2 | Perform Detector Noise & breakdown Testing |  | 76d | 2003-09-02 | 2003-12-19 | 84FF-30d |  |  | 2003-09-02 | 2003-12-19 | 76d | 1d | 0d | start no earlier than 2003-09-02 | STEREO | IMPACT | SEP Package | LET | LET | CIT |
| 88 | 4.2.4.3.3 | Perform Detector Thermal Vac Testing |  | 75d | 2003-09-15 | 2004-01-02 | 87SS+9d |  |  | 2003-09-15 | 2004-01-02 | 75d | 1d | 0d |  | STEREO | IMPACT | SEP Package | LET | LET | CIT |
| 89 | 4.2.4.3.4 | Perform Detector Alphas Testing |  | 76d | 2003-09-02 | 2003-12-19 | 87SS |  |  | 2003-09-02 | 2003-12-19 | 76d | 9d | 8d | start no earlier than 2003-06-30 | STEREO | IMPACT | SEP Package | LET | LET | CIT |
| 90 | 4.2.4.3.5 | Analyze Detector Testing Data |  | 75d | 2003-09-15 | 2004-01-02 | 89SS, 88SS |  |  | 2003-09-15 | 2004-01-02 | 75d | 1d | 0d |  | STEREO | IMPACT | SEP Package | LET | LET | CIT |
| 91 | 4.3 | **VLSI, protoflight** |  | 652d | 2001-06-25 A | 2004-01-30 |  | 73% | 174.07d | 2001-06-25 | 2003-12-12 | 620d | 212d |  |  | STEREO | IMPACT | SEP Package | LET | LET | CIT |
| 92 | 4.3.1 | Design |  | 39d | 2001-06-25 A | 2001-08-17 A |  | 100% |  | 2001-06-25 | 2001-08-17 | 39d |  |  | start no earlier than 2001-06-25 | STEREO | IMPACT | SEP Package | LET | LET | CIT |
| 93 | 4.3.2 | Prepare VLSI design doc (initial) |  | 3d | 2001-06-25 A | 2001-06-27 A | 92SS | 100% |  | 2001-06-25 | 2001-06-27 | 3d |  |  |  | STEREO | IMPACT | SEP Package | LET | LET | CIT |
| 94 | 4.3.3 | Layout |  | 79d | 2001-08-30 A | 2001-12-24 A | 92FS+8d | 100% |  | 2001-08-30 | 2001-12-24 | 79d |  |  |  | STEREO | IMPACT | SEP Package | LET | LET | CIT |
| 95 | 4.3.4 | Submit RFQ to UTMC |  | 1d | 2001-12-26 A | 2001-12-26 A | 94 | 100% |  | 2001-12-26 | 2001-12-26 | 1d |  |  |  | STEREO | IMPACT | SEP Package | LET | LET | CIT |
| 96 | 4.3.5 | DRC and layout check |  | 9d | 2001-12-26 A | 2002-01-08 A | 94 | 100% |  | 2001-12-26 | 2002-01-08 | 9d |  |  |  | STEREO | IMPACT | SEP Package | LET | LET | CIT |
| 97 | 4.3.6 | Independent DRC |  | 3d | 2002-01-09 A | 2002-01-11 A | 96 | 100% |  | 2002-01-09 | 2002-01-11 | 3d |  |  |  | STEREO | IMPACT | SEP Package | LET | LET | CIT |
| 98 | 4.3.7 | Layout Modifications post-DRC |  | 5d | 2002-02-15 A | 2002-02-22 A | 97FS+23d | 100% |  | 2002-02-15 | 2002-02-22 | 5d |  |  |  | STEREO | IMPACT | SEP Package | LET | LET | CIT |
| 99 | 4.3.8 | Layout approval |  | 2d | 2002-02-22 A | 2002-02-25 A | 98 | 100% |  | 2002-02-22 | 2002-02-25 | 2d |  |  |  | STEREO | IMPACT | SEP Package | LET | LET | CIT |
| 100 | 4.3.9 | PO and follow-up on wafer Fabricate |  | 1d | 2002-02-25 A | 2002-02-25 A | 95, 98 | 100% |  | 2002-02-25 | 2002-02-25 | 1d |  |  |  | STEREO | IMPACT | SEP Package | LET | LET | CIT |
| 101 | 4.3.10 | Submit layout for production |  | 2d | 2002-02-26 A | 2002-02-27 A | 99, 100 | 100% |  | 2002-02-26 | 2002-02-27 | 2d |  |  |  | STEREO | IMPACT | SEP Package | LET | LET | CIT |
| 102 | 4.3.11 | VLSI protoflight Fabricate |  | 24d | 2002-02-26 A | 2002-03-29 A | 101 | 100% |  | 2002-02-26 | 2002-03-29 | 24d |  |  |  | STEREO | IMPACT | SEP Package | LET | LET | CIT |
| 103 | 4.3.12 | VLSI packages |  | 1d | 2002-01-02 A | 2002-01-02 A |  | 100% |  | 2002-01-02 | 2002-01-02 | 1d |  |  | start no earlier than 2002-01-02 | STEREO | IMPACT | SEP Package | LET | LET | CIT |
| 104 | 4.3.13 | Final VLSI design doc |  | 20d | 2002-02-28 A | 2003-07-01 A | 101 | 100% |  | 2002-02-28 | 2003-07-01 | 20d |  |  |  | STEREO | IMPACT | SEP Package | LET | LET | CIT |
| 105 | 4.3.14 | Assess hybrid Package/parts req's & Packages |  | 19.1d | 2002-03-06 A | 2002-07-03 A | 94FS+28d | 100% |  | 2002-03-06 | 2002-07-03 | 19.1d |  |  |  | STEREO | IMPACT | SEP Package | LET | LET | CIT |
| 106 | 4.3.15 | Procure hybrid Packages/parts |  | 16d | 2002-03-20 A | 2002-07-22 A | 105FS+10d | 100% |  | 2002-03-20 | 2002-07-22 | 16d |  |  | finish no earlier than 2002-07-22 | STEREO | IMPACT | SEP Package | LET | LET | CIT |
| 107 | 4.3.16 | Design hybrid substrate layout |  | 10d | 2002-03-06 A | 2002-07-16 A | 99, 105 | 100% |  | 2002-03-06 | 2002-07-16 | 10d |  |  |  | STEREO | IMPACT | SEP Package | LET | LET | CIT |
| 108 | 4.3.17 | Review & approve substate layout |  | 3d | 2002-07-17 A | 2002-07-19 A | 107 | 100% |  | 2002-07-17 | 2002-07-19 | 3d |  |  | start no earlier than 2002-06-30 | STEREO | IMPACT | SEP Package | LET | LET | CIT |
| 109 | 4.3.18 | Procure hybrid substrate |  | 5d | 2002-07-22 A | 2002-08-06 A | 108 | 100% |  | 2002-07-22 | 2002-08-06 | 5d |  |  | start no earlier than 2002-06-30 | STEREO | IMPACT | SEP Package | LET | LET | CIT |
| 110 | 4.3.19 | Receive, inspect, database wafer, parts, & Packages |  | 2.75d | 2002-04-08 A | 2003-01-31 A | 103FS+40d, 101FS+60d, 106FS+29d, 109FS+40d | 100% |  | 2002-04-08 | 2003-01-31 | 2.75d |  |  |  | STEREO | IMPACT | SEP Package | LET | LET | CIT |
| 111 | 4.3.20 | Assign pinout & draw hybrid Package |  | 0.3d | 2002-04-17 A | 2002-04-17 A | 106FS-1d | 100% |  | 2002-04-17 | 2002-04-17 | 0.3d |  |  |  | STEREO | IMPACT | SEP Package | LET | LET | CIT |
| 112 | 4.3.21 | Generate Footprints for Schematics & Printed Circuit Board libraries |  | 0.6d | 2002-04-17 A | 2002-04-17 A | 111 | 100% |  | 2002-04-17 | 2002-04-17 | 0.6d |  |  |  | STEREO | IMPACT | SEP Package | LET | LET | CIT |
| 113 | 4.3.22 | Test hybrid packages |  | 19d | 2003-02-03 A | 2003-02-28 A | 110 | 100% |  | 2003-02-03 | 2003-02-28 | 19d |  |  |  | STEREO | IMPACT | SEP Package | LET | LET | CIT |
| 114 | 4.3.23 | Follow-up on test hybrid packaging |  | 10d | 2003-02-03 A | 2003-02-14 A | 113SS | 100% |  | 2003-02-03 | 2003-02-14 | 10d |  |  |  | STEREO | IMPACT | SEP Package | LET | LET | CIT |
| 115 | 4.3.24 | Generate flight hybrid screen flow |  | 17d | 2002-04-17 A | 2003-03-14 A | 106 | 100% |  | 2002-04-17 | 2003-03-14 | 17d |  |  | finish no earlier than 2003-02-07 | STEREO | IMPACT | SEP Package | LET | LET | CIT |
| 116 | 4.3.25 | Design test board schematics |  | 10d | 2002-08-12 A | 2002-08-23 A | 112 | 100% |  | 2002-08-12 | 2002-08-23 | 10d |  |  | start no earlier than 2002-06-30 | STEREO | IMPACT | SEP Package | LET | LET | CIT |
| 117 | 4.3.26 | Design FPGA schematics for test board |  | 5d | 2002-08-26 A | 2002-08-30 A | 116 | 100% |  | 2002-08-26 | 2002-08-30 | 5d |  |  |  | STEREO | IMPACT | SEP Package | LET | LET | CIT |
| 118 | 4.3.27 | Burn-in FPGA |  | 1d | 2003-04-01 A | 2003-04-01 A | 117 | 100% |  | 2003-04-01 | 2003-04-01 | 1d |  |  | start no earlier than 2003-03-31 | STEREO | IMPACT | SEP Package | LET | LET | CIT |
| 119 | 4.3.28 | Obtain samples & footprints for Printed Circuit Board designer |  | 5d | 2002-08-26 A | 2002-08-30 A | 116 | 100% |  | 2002-08-26 | 2002-08-30 | 5d |  |  |  | STEREO | IMPACT | SEP Package | LET | LET | CIT |
| 120 | 4.3.29 | Design test Printed Circuit Board layout |  | 5d | 2002-08-27 A | 2002-09-03 A | 116, 117, 119 | 100% |  | 2002-08-27 | 2002-09-03 | 5d |  |  |  | STEREO | IMPACT | SEP Package | LET | LET | CIT |
| 121 | 4.3.30 | Review and approve Printed Circuit Board layout |  | 1d | 2002-08-30 A | 2002-09-04 A | 120FF+1d | 100% |  | 2002-08-30 | 2002-09-04 | 1d |  |  |  | STEREO | IMPACT | SEP Package | LET | LET | CIT |
| 122 | 4.3.31 | Procure test board and parts |  | 6d | 2002-09-05 A | 2002-09-12 A | 121 | 100% |  | 2002-09-05 | 2002-09-12 | 6d |  |  |  | STEREO | IMPACT | SEP Package | LET | LET | CIT |
| 123 | 4.3.32 | Fabricate test fixture |  | 15d | 2002-09-13 A | 2003-04-03 A | 118, 122 | 100% |  | 2002-09-13 | 2003-04-03 | 15d |  |  | finish no earlier than 2003-04-02 | STEREO | IMPACT | SEP Package | LET | LET | CIT |
| 124 | 4.3.33 | Rework/haywire/trim test board |  | 3d | 2003-04-04 A | 2003-04-08 A | 123 | 100% |  | 2003-04-04 | 2003-04-08 | 3d |  |  | start no earlier than 2003-02-01 | STEREO | IMPACT | SEP Package | LET | LET | CIT |
| 125 | 4.3.34 | Doc test board rework |  | 4d | 2003-04-09 A | 2003-04-14 A | 124 | 100% |  | 2003-04-09 | 2003-04-14 | 4d |  |  | start no earlier than 2003-02-01 | STEREO | IMPACT | SEP Package | LET | LET | CIT |
| 126 | 4.3.35 | VLSI packaging | milestone | 0d | 2003-04-25 A | 2003-04-25 A |  | 100% |  | 2003-04-25 | 2003-04-25 | 0d |  |  |  | STEREO | IMPACT | SEP Package | LET | LET | CIT |
| 127 | 4.3.36 | Deliver hybrid samples to GSFC | milestone | 0d | 2003-05-12 A | 2003-05-12 A |  | 100% |  | 2003-05-12 | 2003-05-12 | 0d |  |  |  | STEREO | IMPACT | SEP Package | LET | LET | CIT |
| 128 | 4.3.37 | Develop screening test fixture & software |  | 39d | 2003-02-03 A | 2003-03-28 A | 120 | 100% |  | 2003-02-03 | 2003-03-28 | 39d |  |  | start no earlier than 2003-02-03 | STEREO | IMPACT | SEP Package | LET | LET | CIT |

Notes:
- 122: Alan started not taking some credit due to project.

| ID | WBS | Task | Type | Duration | Start | Finish | Predecessors | Complete | Remaining | Baseline start | Baseline finish | Baseline duration | Total slack | Free slack | Constraint | Text11 | Text12 | Text13 | Text14 | Text16 | Text28 | Text20 | Text22 | Text23 |
| --- | --- | --- | --- | --- | --- | --- | --- | --- | --- | --- | --- | --- | --- | --- | --- | --- | --- | --- | --- | --- | --- | --- | --- | --- |
| 129 | 4.3.38 | **Hybrids (New Tasks as of 8/1/03)** |  | 92d | 2003-08-01 A | 2003-12-12 |  | 29% | 65.77d | 2003-08-01 | 2003-12-12 | 92d | 244d |  |  | STEREO | IMPACT | SEP Package | LET | LET | CIT |  |  |  |
| 130 | 4.3.38.1 | Package and Test Flight Hybrids Lot 1 (7-10 Parts) |  | 21d | 2003-08-01 A | 2003-08-29 A |  | 100% |  | 2003-08-01 | 2003-09-19 | 35d |  |  | start no earlier than 2003-08-01 | STEREO | IMPACT | SEP Package | LET | LET | CIT |  |  |  |
| 131 | 4.3.38.2 | Select parts for flight |  | 2d | 2003-09-02 | 2003-09-03 | 130 |  |  | 2003-09-22 | 2003-09-23 | 2d | 74d | 0d |  | STEREO | IMPACT | SEP Package | LET | LET | CIT |  |  |  |
| 132 | 4.3.38.3 | Deliver HET Hybrids to GSFC | milestone | 0d | 2003-09-03 | 2003-09-03 | 131 |  |  | 2003-09-23 | 2003-09-23 | 0d | 313d |  |  | STEREO | IMPACT | SEP Package | LET | LET | CIT |  |  |  |
| 133 | 4.3.38.4 | Document screening/selection |  | 3d | 2003-09-04 | 2003-09-08 | 131 |  |  | 2003-09-24 | 2003-09-26 | 3d | 310d |  |  | STEREO | IMPACT | SEP Package | LET | LET | CIT |  |  |  |
| 134 | 4.3.38.5 | Package and Test Flight Hybrids Lot 2 (10 Parts) |  | 24d | 2003-09-02 | 2003-10-03 |  |  |  | 2003-09-02 | 2003-10-03 | 24d | 50d | 0d | start no earlier than 2003-09-02 | STEREO | IMPACT | SEP Package | LET | LET | CIT |  |  |  |
| 135 | 4.3.38.6 | Select parts for flight |  | 2d | 2003-10-07 | 2003-10-08 | 134 |  |  | 2003-10-07 | 2003-10-08 | 2d | 50d | 0d |  | STEREO | IMPACT | SEP Package | LET | LET | CIT |  |  |  |
| 136 | 4.3.38.7 | Document screening/selection |  | 3d | 2003-10-09 | 2003-10-13 | 135 |  |  | 2003-10-09 | 2003-10-13 | 3d | 286d |  |  | STEREO | IMPACT | SEP Package | LET | LET | CIT |  |  |  |
| 137 | 4.3.38.8 | Package and Test Flight Hybrids Lot 3 (20 Parts) |  | 29d | 2003-09-16 | 2003-10-27 |  |  |  | 2003-09-16 | 2003-10-27 | 29d | 271d | 0d | start no earlier than 2003-09-16 | STEREO | IMPACT | SEP Package | LET | LET | CIT |  |  |  |
| 138 | 4.3.38.9 | Select parts for flight |  | 2d | 2003-10-28 | 2003-10-29 | 137 |  |  | 2003-10-28 | 2003-10-29 | 2d | 271d | 0d |  | STEREO | IMPACT | SEP Package | LET | LET | CIT |  |  |  |
| 139 | 4.3.38.10 | Document screening/selection |  | 3d | 2003-10-30 | 2003-11-03 | 138 |  |  | 2003-10-30 | 2003-11-03 | 3d | 271d |  |  | STEREO | IMPACT | SEP Package | LET | LET | CIT |  |  |  |
| 140 | 4.3.38.11 | Support Off Site Application (HET) |  | 92d | 2003-08-01 A | 2003-12-12 |  | 23% | 71d | 2003-08-01 | 2003-12-12 | 92d | 244d |  | start no earlier than 2003-08-01 | STEREO | IMPACT | SEP Package | LET | LET | CIT |  |  |  |
| 141 | 4.3.38.12 | Maintain hard copy docs (sch, parts, Material list) |  | 40d | 2003-08-01 A | 2003-09-26 | 130SS | 53% | 19d | 2003-08-01 | 2003-09-26 | 40d | 296d |  |  | STEREO | IMPACT | SEP Package | LET | LET | CIT |  |  |  |
| 142 | 4.3.39 | **Procurements** |  | 159d | 2002-07-01 A | 2003-02-19 A |  | 100% |  | 2002-07-01 | 2003-02-19 | 159d |  |  |  | STEREO | IMPACT | SEP Package | LET | LET | CIT |  |  |  |
| 143 | 4.3.39.1 | **ETU** |  | 21d | 2002-07-01 A | 2002-07-30 A |  | 100% |  | 2002-07-01 | 2002-07-30 | 21d |  |  |  | STEREO | IMPACT | SEP Package | LET | LET | GSFC |  |  |  |
| 144 | 4.3.39.1.1 | Place Order For LET ETU Mounts |  | 2d | 2002-07-01 A | 2002-07-02 A | 153, 154, 155 | 100% |  | 2002-07-01 | 2002-07-02 | 2d |  |  | start no earlier than 2002-07-31 | STEREO | IMPACT | SEP Package | LET | LET | GSFC |  |  |  |
| 145 | 4.3.39.1.2 | Place Order For LET L1 Prototype Detectors |  | 2d | 2002-07-29 A | 2002-07-30 A | 166 | 100% |  | 2002-07-29 | 2002-07-30 | 2d |  |  | start no earlier than 2002-08-30 | STEREO | IMPACT | SEP Package | LET | LET | GSFC |  |  |  |
| 146 | 4.3.39.1.3 | Place Order For LET L2-L3 Prototype Detectors |  | 2d | 2002-07-29 A | 2002-07-30 A | 167, 168 | 100% |  | 2002-07-29 | 2002-07-30 | 2d |  |  | start no earlier than 2002-08-30 | STEREO | IMPACT | SEP Package | LET | LET | GSFC |  |  |  |
| 147 | 4.3.39.2 | **FM 1 & FM 2** |  | 130d | 2002-08-12 A | 2003-02-19 A |  | 100% |  | 2002-08-12 | 2003-02-19 | 130d |  |  |  | STEREO | IMPACT | SEP Package | LET | LET | GSFC |  |  |  |
| 148 | 4.3.39.2.1 | Place Order For LET Flight Mounts |  | 2d | 2002-08-12 A | 2002-08-13 A | 153, 154, 155 | 100% |  | 2002-08-12 | 2002-08-13 | 2d |  |  | start no earlier than 2002-07-31 | STEREO | IMPACT | SEP Package | LET | LET | GSFC |  |  |  |
| 149 | 4.3.39.2.2 | Order LET Flight Detectors |  | 1d | 2003-02-19 A | 2003-02-19 A | 150, 151 | 100% |  | 2003-02-19 | 2003-02-19 | 1d |  |  |  | STEREO | IMPACT | SEP Package | LET | LET | CIT | Order LET Flight Detectors | LET - Place Flight Detector Order | Order Flight Detectors |
| 150 | 4.3.39.2.3 | Place Order For LET L1 Flight Detectors |  | 2d | 2003-02-17 A | 2003-02-19 A | 173 | 100% |  | 2003-02-17 | 2003-02-19 | 2d |  |  | start no earlier than 2003-02-28 | STEREO | IMPACT | SEP Package | LET | LET | GSFC |  |  |  |
| 151 | 4.3.39.2.4 | Place Order For LET L2-L3 Flight Detectors |  | 2d | 2003-02-17 A | 2003-02-19 A | 174, 175 | 100% |  | 2003-02-17 | 2003-02-19 | 2d |  |  | start no earlier than 2003-02-28 | STEREO | IMPACT | SEP Package | LET | LET | GSFC |  |  |  |
| 152 | 4.3.40 | **Design** |  | 284.2d | 2002-05-15 A | 2003-07-02 A |  | 100% |  | 2002-05-15 | 2003-07-02 | 284.2d |  |  |  | STEREO | IMPACT | SEP Package | LET | LET | GSFC |  |  |  |
| 153 | 4.3.40.1 | Design LET L1 Mount |  | 11.84d | 2002-05-15 A | 2002-05-31 A | 37 | 100% |  | 2002-05-15 | 2002-05-31 | 11.84d |  |  | start no earlier than 2002-04-30 | STEREO | IMPACT | SEP Package | LET | LET | GSFC |  |  |  |
| 154 | 4.3.40.2 | Design LET L2 Mount |  | 16d | 2002-05-29 A | 2002-06-19 A | 37 | 100% |  | 2002-05-29 | 2002-06-19 | 16d |  |  | start no earlier than 2002-04-30 | STEREO | IMPACT | SEP Package | LET | LET | GSFC |  |  |  |
| 155 | 4.3.40.3 | Design LET L3 Mount |  | 16d | 2002-06-03 A | 2002-06-24 A | 37 | 100% |  | 2002-06-03 | 2002-06-24 | 16d |  |  | start no earlier than 2002-06-30 | STEREO | IMPACT | SEP Package | LET | LET | GSFC |  |  |  |
| 156 | 4.1.2.5 | Design H3-H6 Mounts |  | 7d | 2002-05-22 A | 2002-06-26 A | 155, 154 | 100% |  | 2002-05-22 | 2002-06-26 | 7d |  |  | start no earlier than 2002-04-30 | STEREO | IMPACT | SEP Package | LET | LET | CIT |  |  |  |
| 157 | 4.1.2.3 | Design H1-H2 Mounts |  | 19d | 2002-05-01 A | 2002-05-28 A | 155, 154 | 100% |  | 2002-05-01 | 2002-05-28 | 19d |  |  | start no earlier than 2002-04-30 | STEREO | IMPACT | SEP Package | LET | LET | CIT |  |  |  |
| 158 | 4.3.40.6 | Design LET L1 Detector Test Holder |  | 6d | 2003-04-01 A | 2003-04-08 A | 153, 155FS+9d | 100% |  | 2003-04-01 | 2003-04-08 | 6d |  |  | start no earlier than 2003-03-31 | STEREO | IMPACT | SEP Package | LET | LET | GSFC |  |  |  |
| 159 | 4.3.40.7 | Design LET L2 Detector Test Holder |  | 6d | 2003-04-01 A | 2003-04-08 A | 154FS+9d | 100% |  | 2003-04-01 | 2003-04-08 | 6d |  |  | start no earlier than 2003-03-31 | STEREO | IMPACT | SEP Package | LET | LET | GSFC |  |  |  |
| 160 | 4.3.40.8 | Design LET L3 Detector Test Holder |  | 6d | 2003-04-01 A | 2003-07-02 A | 155FS+9d | 100% |  | 2003-04-01 | 2003-07-02 | 6d |  |  | start no earlier than 2003-03-31 | STEREO | IMPACT | SEP Package | LET | LET | GSFC |  |  |  |

| ID | WBS | Task | Type | Duration | Start | Finish | Predecessors | Complete | Remaining | Baseline start | Baseline finish | Baseline duration | Total slack | Free slack | Constraint | Text11 | Text12 | Text13 | Text14 | Text16 | Text28 | Text20 | Text22 | Text23 | Text21 |
| --- | --- | --- | --- | --- | --- | --- | --- | --- | --- | --- | --- | --- | --- | --- | --- | --- | --- | --- | --- | --- | --- | --- | --- | --- | --- |
| 161 | 4.3.41 | **Fabrication** |  | 380d | 2002-07-25 A | 2004-01-30 |  | 65% | 134.12d | 2002-07-25 | 2003-09-18 | 290d | 212d |  |  | STEREO | IMPACT | SEP Package | LET | LET | GSFC |  |  |  |  |
| 162 | 4.3.41.1 | Receive & Inspect LET L1 Detector Test Holder |  | 2d | 2003-04-01 A | 2003-04-02 A |  | 100% |  | 2003-04-01 | 2003-04-02 | 2d |  |  | start no earlier than 2003-03-31 | STEREO | IMPACT | SEP Package | LET | LET | GSFC |  |  |  |  |
| 163 | 4.3.41.2 | Receive & Inspect LET L2 Detector Test Holder |  | 2d | 2003-04-01 A | 2003-05-01 A |  | 100% |  | 2003-04-01 | 2003-05-01 | 2d |  |  | start no earlier than 2003-03-31 | STEREO | IMPACT | SEP Package | LET | LET | GSFC |  |  |  |  |
| 164 | 4.3.41.3 | Receive & Inspect LET L3 Detector Test Holder |  | 2d | 2003-05-01 A | 2003-07-01 A |  | 100% |  | 2003-05-01 | 2003-07-01 | 2d |  |  | start no earlier than 2003-04-30 | STEREO | IMPACT | SEP Package | LET | LET | GSFC |  |  |  |  |
| 165 | 4.3.41.4 | **ETU** |  | 192.2d | 2002-07-25 A | 2003-05-01 A |  | 100% |  | 2002-07-25 | 2003-05-01 | 192.2d |  |  |  | STEREO | IMPACT | SEP Package | LET | LET | GSFC |  |  |  |  |
| 166 | 4.3.41.4.1 | Receive & Inspect LET L1 ETU Mounts |  | 2d | 2002-07-25 A | 2002-07-26 A | 144FS+10d | 100% |  | 2002-07-25 | 2002-07-26 | 2d |  |  | start no earlier than 2002-07-31 | STEREO | IMPACT | SEP Package | LET | LET | GSFC |  |  |  |  |
| 167 | 4.3.41.4.2 | Receive & Inspect LET L2 ETU Mounts |  | 2d | 2002-07-25 A | 2002-07-26 A | 144FS+10d | 100% |  | 2002-07-25 | 2002-07-26 | 2d |  |  | start no earlier than 2002-07-31 | STEREO | IMPACT | SEP Package | LET | LET | GSFC |  |  |  |  |
| 168 | 4.3.41.4.3 | Receive & Inspect LET L3 ETU Mounts |  | 2d | 2002-07-25 A | 2002-07-26 A | 144FS+10d | 100% |  | 2002-07-25 | 2002-07-26 | 2d |  |  | start no earlier than 2002-07-31 | STEREO | IMPACT | SEP Package | LET | LET | GSFC |  |  |  |  |
| 169 | 4.3.41.4.4 | Receive & Inspect LET L1 Prototype Detector |  | 2d | 2002-11-20 A | 2002-11-21 A | 145FS+77d | 100% |  | 2002-11-20 | 2002-11-21 | 2d |  |  |  | STEREO | IMPACT | SEP Package | LET | LET | GSFC |  |  |  |  |
| 170 | 4.3.41.4.5 | Receive & Inspect LET L2 & L3 Prototype Detectors |  | 2d | 2003-04-01 A | 2003-05-01 A | 146FS+31d | 100% |  | 2003-04-01 | 2003-05-01 | 2d |  |  | start no earlier than 2003-03-31 | STEREO | IMPACT | SEP Package | LET | LET | GSFC |  |  |  |  |
| 171 | 4.3.41.5 | **FM 1 & FM 2** |  | 188d | 2003-05-01 A | 2004-01-30 |  | 33% | 125.33d | 2003-05-01 | 2003-09-18 | 98d | 212d |  |  | STEREO | IMPACT | SEP Package | LET | LET | GSFC |  |  |  |  |
| 172 | 4.3.41.5.1 | LET Last Flight Detector Received | milestone | 0d | 2004-01-30 | 2004-01-30 | 149FS+148d, 69, 70 |  |  | 2003-09-18 | 2003-09-18 | 0d | 5d |  | finish no later than 2004-02-06 | STEREO | IMPACT | SEP Package | LET | LET | CIT | All LET Flight Detectors Received | LET - All Flight Detectors Received | Last Flight Detector Received |  |
| 173 | 4.3.41.5.2 | Receive & Inspect LET L1 FM 1 & FM 2 Mounts |  | 2d | 2003-08-01 A | 2003-08-04 A | 148FS+10d | 100% |  | 2003-05-01 | 2003-05-02 | 2d |  |  | start no earlier than 2003-08-01 | STEREO | IMPACT | SEP Package | LET | LET | GSFC |  |  |  |  |
| 174 | 4.3.41.5.3 | Receive & Inspect LET L2 FM 1 & FM 2 Mounts |  | 2d | 2003-08-01 A | 2003-08-04 A | 148FS+10d | 100% |  | 2003-05-01 | 2003-05-02 | 2d |  |  | start no earlier than 2003-08-01 | STEREO | IMPACT | SEP Package | LET | LET | GSFC |  |  |  |  |
| 175 | 4.3.41.5.4 | Receive & Inspect LET L3 FM 1 & FM 2 Mounts |  | 2d | 2003-05-01 A | 2003-05-02 A | 148FS+10d | 100% |  | 2003-05-01 | 2003-05-02 | 2d |  |  | start no earlier than 2003-04-30 | STEREO | IMPACT | SEP Package | LET | LET | GSFC |  |  |  |  |
| 176 | 4.3.41.5.5 | **FM 1** |  | 11d | 2003-06-18 | 2003-07-02 |  |  |  | 2003-06-18 | 2003-07-02 | 11d | 319d |  |  | STEREO | IMPACT | SEP Package | LET | LET | CIT |  |  |  |  |
| 177 | 4.3.41.5.5.1 | Receive & Inspect LET FM 1 L1 Flight Detector |  | 2d | 2003-06-18 | 2003-06-19 | 150FS+83d |  |  | 2003-06-18 | 2003-06-19 | 2d | 365d |  |  | STEREO | IMPACT | SEP Package | LET | LET | CIT |  |  |  |  |
| 178 | 4.3.41.5.5.2 | Receive & Inspect LET FM 1 L2 Flight Detector |  | 2d | 2003-07-01 | 2003-07-02 | 151FS+83d |  |  | 2003-07-01 | 2003-07-02 | 2d | 310d | 0d | start no earlier than 2003-06-30 | STEREO | IMPACT | SEP Package | LET | LET | CIT |  |  |  |  |
| 179 | 4.3.41.5.5.3 | Receive & Inspect LET FM 1 L3 Flight Detector |  | 2d | 2003-07-01 | 2003-07-02 | 151FS+83d |  |  | 2003-07-01 | 2003-07-02 | 2d | 310d | 0d | start no earlier than 2003-06-30 | STEREO | IMPACT | SEP Package | LET | LET | CIT |  |  |  |  |
| 180 | 4.3.41.5.6 | **FM 2** |  | 11d | 2003-06-18 | 2003-07-02 |  |  |  | 2003-06-18 | 2003-07-02 | 11d | 319d |  |  | STEREO | IMPACT | SEP Package | LET | LET | CIT |  |  |  |  |
| 181 | 4.3.41.5.6.1 | Receive & Inspect LET FM 2 L1 Flight Detector |  | 2d | 2003-06-18 | 2003-06-19 | 150FS+83d |  |  | 2003-06-18 | 2003-06-19 | 2d | 365d |  |  | STEREO | IMPACT | SEP Package | LET | LET | CIT |  |  |  |  |
| 182 | 4.3.41.5.6.2 | Receive & Inspect LET FM 2 L2 Flight Detector |  | 2d | 2003-07-01 | 2003-07-02 | 151FS+83d |  |  | 2003-07-01 | 2003-07-02 | 2d | 310d | 0d | start no earlier than 2003-06-30 | STEREO | IMPACT | SEP Package | LET | LET | CIT |  |  |  |  |
| 183 | 4.3.41.5.6.3 | Receive & Inspect LET FM 2 L3 Flight Detector |  | 2d | 2003-07-01 | 2003-07-02 | 151FS+83d |  |  | 2003-07-01 | 2003-07-02 | 2d | 310d | 0d | start no earlier than 2003-06-30 | STEREO | IMPACT | SEP Package | LET | LET | CIT |  |  |  |  |
| 184 | 4.3.42 | **Test** |  | 136d | 2003-05-01 A | 2003-11-13 |  | 65% | 47.24d | 2003-05-01 | 2003-11-13 | 136d | 264d |  |  | STEREO | IMPACT | SEP Package | LET | LET | CIT |  |  |  |  |
| 185 | 4.3.42.1 | **ETU** |  | 85d | 2003-05-01 A | 2003-08-29 A |  | 100% |  | 2003-05-01 | 2003-10-09 | 112d |  |  |  | STEREO | IMPACT | SEP Package | LET | LET | CIT |  |  |  |  |
| 186 | 4.3.42.1.1 | Evaluate LET L1 Prototype Detector |  | 69d | 2003-05-01 A | 2003-08-07 A | 169FS-50d, 162 | 100% |  | 2003-05-01 | 2003-08-07 | 69d |  |  | start no earlier than 2003-04-30 | STEREO | IMPACT | SEP Package | LET | LET | GSFC |  |  |  | LET Detect. Tested |
| 187 | 4.3.42.1.2 | Evaluate LET L2 & L3 Prototype Detectors |  | 42d | 2003-07-02 A | 2003-08-29 A | 170FS-80d, 164, 163 | 100% |  | 2003-07-02 | 2003-10-09 | 69d |  |  | start no earlier than 2003-04-30 | STEREO | IMPACT | SEP Package | LET | LET | GSFC |  |  |  |  |

Notes:
- 187: This is a CIT Function GSFC is evaluating L1 only for CIT

| ID | WBS | Task | Type | Duration | Start | Finish | Predecessors | Complete | Remaining | Baseline start | Baseline finish | Baseline duration | Total slack | Free slack | Constraint | Text11 | Text12 | Text13 | Text14 | Text16 | Text28 | Text23 |
| --- | --- | --- | --- | --- | --- | --- | --- | --- | --- | --- | --- | --- | --- | --- | --- | --- | --- | --- | --- | --- | --- | --- |
| 188 | 4.3.42.2 | **FM 1 & FM 2** |  | 86d | 2003-07-14 A | 2003-11-13 |  | 40% | 51.83d | 2003-07-14 | 2003-11-13 | 86d | 264d |  |  | STEREO | IMPACT | SEP Package | LET | LET | GSFC |  |
| 189 | 4.3.42.2.1 | Capacitance, Current, Depletion, Alpha Resolution |  | 75d | 2003-07-14 A | 2003-10-28 | 182FS+6d, 183FS+6d, 178FS+6d, 179FS+6d | 47% | 40d | 2003-07-14 | 2003-10-28 | 75d | 275d | 0d | start no earlier than 2003-06-30 | STEREO | IMPACT | SEP Package | LET | LET | GSFC |  |
| 190 | 4.3.42.2.2 | Life Test LET Flight Detectors |  | 76d | 2003-07-28 A | 2003-11-13 | 189SS+10d | 33% | 51d | 2003-07-28 | 2003-11-13 | 76d | 34d | 33d |  | STEREO | IMPACT | SEP Package | LET | LET | GSFC | Flight Detectors Life Tested |
| 191 | 5 | **(OBSOLETE) MISC Board** |  | 396d | 2001-12-03 A | 2003-06-30 A |  | 100% |  | 2001-12-03 | 2003-06-30 | 396d |  |  |  | STEREO | IMPACT | SEP Package | LET | LET | CIT |  |
| 192 | 5.1 | **Design, Manufacture, Assembly and Test** |  | 396d | 2001-12-03 A | 2003-06-30 A |  | 100% |  | 2001-12-03 | 2003-06-30 | 396d |  |  |  | STEREO | IMPACT | SEP Package | LET | LET | CIT |  |
| 193 | 5.1.1 | **Procurements** |  | 396d | 2001-12-03 A | 2003-06-30 A |  | 100% |  | 2001-12-03 | 2003-06-30 | 396d |  |  |  | STEREO | IMPACT | SEP Package | LET | LET | CIT |  |
| 194 | 5.1.1.1 | **ETU** |  | 396d | 2001-12-03 A | 2003-06-30 A |  | 100% |  | 2001-12-03 | 2003-06-30 | 396d |  |  |  | STEREO | IMPACT | SEP Package | LET | LET | CIT |  |
| 195 | 5.1.1.1.1 | Procure LET MISC Board Actel 54SX72A FPGA - EM | milestone | 0d | 2001-12-03 A | 2003-06-30 A |  | 100% |  | 2001-12-03 | 2003-06-30 | 0d |  |  | finish no earlier than 2002-08-01 | STEREO | IMPACT | SEP Package | LET | LET | CIT |  |
| 196 | 5.1.1.1.2 | Procure LET MISC Board SRAM 128K x 8, 3.3V - EM |  | 29d | 2002-07-01 A | 2003-01-14 A |  | 100% |  | 2002-07-01 | 2003-01-14 | 29d |  |  | finish no earlier than 2002-08-01 | STEREO | IMPACT | SEP Package | LET | LET | CIT |  |
| 197 | 5.1.1.1.3 | Procure LET MISC Board EM Parts |  | 8d | 2003-05-01 A | 2003-05-12 A | 211, 212 | 100% |  | 2003-05-01 | 2003-05-12 | 8d |  |  | start no earlier than 2003-04-30 | STEREO | IMPACT | SEP Package | LET | LET | CIT |  |
| 198 | 5.1.1.1.4 | Procure LET MISC Board EM Printed Circuit Board | milestone | 0d | 2003-06-30 A | 2003-06-30 A | 215 | 100% |  | 2003-06-30 | 2003-06-30 | 0d |  |  | start no earlier than 2003-04-30 | STEREO | IMPACT | SEP Package | LET | LET | CIT |  |
| 199 | 5.1.1.2 | **FM 1 & FM 2** |  | 251d | 2002-07-01 A | 2003-06-30 A |  | 100% |  | 2002-07-01 | 2003-06-30 | 251d |  |  |  | STEREO | IMPACT | SEP Package | LET | LET | CIT |  |
| 200 | 5.1.1.2.1 | Procure LET MISC Board Actel RTSX72S FPGA - flight |  | 1d | 2002-07-01 A | 2002-07-01 A |  | 100% |  | 2002-07-01 | 2002-07-01 | 1d |  |  | start no earlier than 2002-07-01 | STEREO | IMPACT | SEP Package | LET | LET | CIT |  |
| 201 | 5.1.1.2.2 | Procure LET MISC Board SRAM 128K x 8, 3.3V - flight | milestone | 0d | 2002-07-01 A | 2003-06-30 A |  | 100% |  | 2002-07-01 | 2003-06-30 | 0d |  |  |  | STEREO | IMPACT | SEP Package | LET | LET | CIT |  |
| 202 | 5.1.1.2.3 | Procure LET MISC Board Clock Oscillator, 32 MHz |  | 0.3d | 2002-07-02 A | 2003-06-30 A |  | 100% |  | 2002-07-02 | 2003-06-30 | 0.3d |  |  | start no earlier than 2002-07-01 | STEREO | IMPACT | SEP Package | LET | LET | CIT |  |
| 203 | 5.1.1.2.4 | Procure LET MISC Board MISC Board Flight Parts | milestone | 0d | 2003-06-30 A | 2003-06-30 A | 261 | 100% |  | 2003-06-30 | 2003-06-30 | 0d |  |  |  | STEREO | IMPACT | SEP Package | LET | LET | CIT |  |
| 204 | 5.1.1.2.5 | Procure LET MISC Board flight Printed Circuit Board | milestone | 0d | 2003-06-30 A | 2003-06-30 A | 222 | 100% |  | 2003-06-30 | 2003-06-30 | 0d |  |  |  | STEREO | IMPACT | SEP Package | LET | LET | CIT |  |
| 205 | 5.1.2 | **Design** |  | 250d | 2002-07-02 A | 2003-06-30 A |  | 100% |  | 2002-07-02 | 2003-06-30 | 250d |  |  |  | STEREO | IMPACT | SEP Package | LET | LET | CIT |  |
| 206 | 5.1.2.1 | **ETU** |  | 250d | 2002-07-02 A | 2003-06-30 A |  | 100% |  | 2002-07-02 | 2003-06-30 | 250d |  |  |  | STEREO | IMPACT | SEP Package | LET | LET | CIT |  |
| 207 | 5.1.2.1.1 | Design and sketch LET MISC Printed Circuit Board schematics for EM |  | 40d | 2002-07-02 A | 2002-11-06 A | 298SS | 100% |  | 2002-07-02 | 2002-11-06 | 40d |  |  | start no earlier than 2002-07-01 | STEREO | IMPACT | SEP Package | LET | LET | CIT |  |
| 208 | 4.1.2.1.3 | Design and sketch Printed Circuit Board schematics for SEP Central Logic EM |  | 56.7d | 2002-07-02 A | 2002-11-12 A | 207SS | 100% |  | 2002-07-02 | 2002-11-12 | 56.7d |  |  |  | STEREO | IMPACT | SEP Package | LET | LET | CIT |  |
| 209 | 5.1.2.1.3 | Design LET MISC Printed Circuit Board schematics for EM version |  | 5d | 2002-11-07 A | 2002-11-14 A | 207 | 100% |  | 2002-11-07 | 2002-11-14 | 5d |  |  | start no earlier than 2002-10-31 | STEREO | IMPACT | SEP Package | LET | LET | CIT |  |
| 210 | 5.1.2.1.4 | Design FPGA Schematics/EEPROM for LET MISC Board EM version |  | 10d | 2002-11-15 A | 2002-12-02 A | 209 | 100% |  | 2002-11-15 | 2002-12-02 | 10d |  |  | start no earlier than 2002-10-31 | STEREO | IMPACT | SEP Package | LET | LET | CIT |  |
| 211 | 5.1.2.1.5 | FMA/design review/risk assessment for LET MISC Board |  | 4d | 2002-12-03 A | 2002-12-06 A | 209, 210 | 100% |  | 2002-12-03 | 2002-12-06 | 4d |  |  | start no earlier than 2002-10-31 | STEREO | IMPACT | SEP Package | LET | LET | CIT |  |
| 212 | 5.1.2.1.6 | Assess MISC Board EM and Flight Parts |  | 8d | 2002-11-15 A | 2002-11-26 A | 209 | 100% |  | 2002-11-15 | 2002-11-26 | 8d |  |  | start no earlier than 2002-10-31 | STEREO | IMPACT | SEP Package | LET | LET | CIT |  |
| 213 | 5.1.2.1.7 | Obtain samples & Footprints, provide to LET MISC Printed Circuit Board designer |  | 1d | 2002-11-27 A | 2002-11-27 A | 212 | 100% |  | 2002-11-27 | 2002-11-27 | 1d |  |  | start no earlier than 2002-10-31 | STEREO | IMPACT | SEP Package | LET | LET | CIT |  |
| 214 | 5.1.2.1.8 | Design EM LET MISC Printed Circuit Board layout |  | 10d | 2003-01-20 A | 2003-06-30 A | 209FS+20d, 211FS+20d, 213FS+20d | 100% |  | 2003-01-20 | 2003-06-30 | 10d |  |  | start no earlier than 2003-01-20 | STEREO | IMPACT | SEP Package | LET | LET | CIT |  |
| 215 | 5.1.2.1.9 | Review & approve EM LET MISC Printed Circuit Board layout | milestone | 0d | 2003-06-30 A | 2003-06-30 A | 214 | 100% |  | 2003-06-30 | 2003-06-30 | 0d |  |  | start no earlier than 2003-04-30 | STEREO | IMPACT | SEP Package | LET | LET | CIT |  |
| 216 | 5.1.2.1.10 | Doc EM LET MISC Board rework (traveler, ECR) | milestone | 0d | 2003-06-30 A | 2003-06-30 A | 234 | 100% |  | 2003-06-30 | 2003-06-30 | 0d |  |  |  | STEREO | IMPACT | SEP Package | LET | LET | CIT |  |

Notes:
- 191: March 03 Status - This board is obsolete. It was combined with the Detector Board.
- 197: Alan started but project again.MS Project problem @ ?%
- 203: At 25% but MS Project problem
- 212: Alan started but project generates incorrect data for out of sequence activities.
- 213: Alan says at 10 % project problem.

| ID | WBS | Task | Type | Duration | Start | Finish | Predecessors | Complete | Baseline start | Baseline finish | Baseline duration | Constraint | Text11 | Text12 | Text13 | Text14 | Text16 | Text28 |
| --- | --- | --- | --- | --- | --- | --- | --- | --- | --- | --- | --- | --- | --- | --- | --- | --- | --- | --- |
| 217 | 5.1.2.2 | **FM 1 & FM 2** |  | 21d | 2003-05-30 A | 2003-06-30 A |  | 100% | 2003-05-30 | 2003-06-30 | 21d |  | STEREO | IMPACT | SEP Package | LET | LET | CIT |
| 218 | 5.1.2.2.1 | Revise/update LET MISC Printed Circuit Board schematics for flight version | milestone | 0d | 2003-06-30 A | 2003-06-30 A | 262 | 100% | 2003-06-30 | 2003-06-30 | 0d |  | STEREO | IMPACT | SEP Package | LET | LET | CIT |
| 219 | 5.1.2.2.2 | Revise/update FPGA Schematics/EEPROM for LET MISC Board Flight Version |  | 21d | 2003-05-30 A | 2003-06-30 A | 262 | 100% | 2003-05-30 | 2003-06-30 | 21d |  | STEREO | IMPACT | SEP Package | LET | LET | CIT |
| 220 | 5.1.2.2.3 | Obtain samples & Footprints, provide to LET MISC Printed Circuit Board designer | milestone | 0d | 2003-06-30 A | 2003-06-30 A | 203 | 100% | 2003-06-30 | 2003-06-30 | 0d |  | STEREO | IMPACT | SEP Package | LET | LET | CIT |
| 221 | 5.1.2.2.4 | Revise/update LET MISC Printed Circuit Board layout for flight version | milestone | 0d | 2003-06-30 A | 2003-06-30 A | 218, 219, 220 | 100% | 2003-06-30 | 2003-06-30 | 0d |  | STEREO | IMPACT | SEP Package | LET | LET | CIT |
| 222 | 5.1.2.2.5 | Review & approve flight LET MISC Printed Circuit Board layout | milestone | 0d | 2003-06-30 A | 2003-06-30 A | 221 | 100% | 2003-06-30 | 2003-06-30 | 0d |  | STEREO | IMPACT | SEP Package | LET | LET | CIT |
| 223 | 5.1.2.2.6 | Doc flight LET MISC Board rework (traveler, ECR) | milestone | 0d | 2003-06-30 A | 2003-06-30 A | 249, 246 | 100% | 2003-06-30 | 2003-06-30 | 0d |  | STEREO | IMPACT | SEP Package | LET | LET | CIT |
| 224 | 5.1.2.2.7 | Final update of LET MISC Printed Circuit Board schematics & layout | milestone | 0d | 2003-06-30 A | 2003-06-30 A | 223 | 100% | 2003-06-30 | 2003-06-30 | 0d |  | STEREO | IMPACT | SEP Package | LET | LET | CIT |
| 225 | 5.1.3 | **Fabrication** |  | 42d | 2003-05-01 A | 2003-06-30 A |  | 100% | 2003-05-01 | 2003-06-30 | 42d |  | STEREO | IMPACT | SEP Package | LET | LET | CIT |
| 226 | 5.1.3.1 | **ETU** |  | 0d | 2003-06-30 A | 2003-06-30 A |  | 100% | 2003-06-30 | 2003-06-30 | 0d |  | STEREO | IMPACT | SEP Package | LET | LET | CIT |
| 227 | 5.1.3.1.1 | Receive/inspect/database EM parts for LET MISC Board | milestone | 0d | 2003-06-30 A | 2003-06-30 A | 195FS+5d, 196FS+38d, 197FS+5d | 100% | 2003-06-30 | 2003-06-30 | 0d | start no earlier than 2003-04-30 | STEREO | IMPACT | SEP Package | LET | LET | CIT |
| 228 | 5.1.3.1.2 | Generate EM kit list in database for LET MISC Board | milestone | 0d | 2003-06-30 A | 2003-06-30 A | 227 | 100% | 2003-06-30 | 2003-06-30 | 0d | start no earlier than 2003-04-30 | STEREO | IMPACT | SEP Package | LET | LET | CIT |
| 229 | 5.1.3.1.3 | Burn in EM FPGA/EEPROM for LET MISC Board | milestone | 0d | 2003-06-30 A | 2003-06-30 A | 227, 210 | 100% | 2003-06-30 | 2003-06-30 | 0d | start no earlier than 2003-04-30 | STEREO | IMPACT | SEP Package | LET | LET | CIT |
| 230 | 5.1.3.1.4 | Bend leads on EM Ics for LET MISC Board | milestone | 0d | 2003-06-30 A | 2003-06-30 A | 227 | 100% | 2003-06-30 | 2003-06-30 | 0d | start no earlier than 2003-04-30 | STEREO | IMPACT | SEP Package | LET | LET | CIT |
| 231 | 5.1.3.1.5 | Inspect EM LET MISC Printed Circuit Board | milestone | 0d | 2003-06-30 A | 2003-06-30 A | 198FS+13d | 100% | 2003-06-30 | 2003-06-30 | 0d | start no earlier than 2003-06-30 | STEREO | IMPACT | SEP Package | LET | LET | CIT |
| 232 | 5.1.3.1.6 | Generate EM kit book for LET MISC Board | milestone | 0d | 2003-06-30 A | 2003-06-30 A | 228 | 100% | 2003-06-30 | 2003-06-30 | 0d | start no earlier than 2003-04-30 | STEREO | IMPACT | SEP Package | LET | LET | CIT |
| 233 | 5.1.3.1.7 | Kit EM parts for LET MISC Board | milestone | 0d | 2003-06-30 A | 2003-06-30 A | 232 | 100% | 2003-06-30 | 2003-06-30 | 0d | start no earlier than 2003-04-30 | STEREO | IMPACT | SEP Package | LET | LET | CIT |
| 234 | 5.1.3.1.8 | Rework/haywire/trim EM for LET MISC Printed Circuit Board | milestone | 0d | 2003-06-30 A | 2003-06-30 A | 261 | 100% | 2003-06-30 | 2003-06-30 | 0d |  | STEREO | IMPACT | SEP Package | LET | LET | CIT |
| 235 | 5.1.3.2 | **FM 1 & FM 2** |  | 42d | 2003-05-01 A | 2003-06-30 A |  | 100% | 2003-05-01 | 2003-06-30 | 42d |  | STEREO | IMPACT | SEP Package | LET | LET | CIT |
| 236 | 5.1.3.2.1 | Receive/inspect/database flight parts for LET MISC Board | milestone | 0d | 2003-06-30 A | 2003-06-30 A | 200FS+90d, 201FS+120d, 202FS+140d, 203FS+29d | 100% | 2003-06-30 | 2003-06-30 | 0d |  | STEREO | IMPACT | SEP Package | LET | LET | CIT |
| 237 | 5.1.3.2.2 | Generate flight kit list in database for LET MISC Board |  | 21d | 2003-05-30 A | 2003-06-30 A | 236 | 100% | 2003-05-30 | 2003-06-30 | 21d |  | STEREO | IMPACT | SEP Package | LET | LET | CIT |
| 238 | 5.1.3.2.3 | Rescreen heritage flight parts for LET MISC Board |  | 2d | 2003-05-01 A | 2003-05-02 A | 212 | 100% | 2003-05-01 | 2003-05-02 | 2d | start no earlier than 2003-04-30 | STEREO | IMPACT | SEP Package | LET | LET | CIT |
| 239 | 5.1.3.2.4 | Burn-in flight FPGA/EEPROM for LET MISC Board | milestone | 0d | 2003-06-30 A | 2003-06-30 A | 236, 218 | 100% | 2003-06-30 | 2003-06-30 | 0d |  | STEREO | IMPACT | SEP Package | LET | LET | CIT |
| 240 | 5.1.3.2.5 | Bend leads on flight Ics for LET MISC Board | milestone | 0d | 2003-06-30 A | 2003-06-30 A | 236, 222 | 100% | 2003-06-30 | 2003-06-30 | 0d |  | STEREO | IMPACT | SEP Package | LET | LET | CIT |
| 241 | 5.1.3.2.6 | Inspect flight for LET MISC Printed Circuit Boards (coupons & elec continuity) | milestone | 0d | 2003-06-30 A | 2003-06-30 A | 204FS+14d | 100% | 2003-06-30 | 2003-06-30 | 0d |  | STEREO | IMPACT | SEP Package | LET | LET | CIT |
| 242 | 5.1.3.2.7 | Generate flight kit book for LET MISC Board | milestone | 0d | 2003-06-30 A | 2003-06-30 A | 237 | 100% | 2003-06-30 | 2003-06-30 | 0d |  | STEREO | IMPACT | SEP Package | LET | LET | CIT |
| 243 | 5.1.3.2.8 | Kit flight parts for LET MISC Board | milestone | 0d | 2003-06-30 A | 2003-06-30 A | 242 | 100% | 2003-06-30 | 2003-06-30 | 0d |  | STEREO | IMPACT | SEP Package | LET | LET | CIT |

Notes:
- 233: Dropped SS pred with 322

| ID | WBS | Task | Type | Duration | Start | Finish | Predecessors | Complete | Baseline start | Baseline finish | Baseline duration | Constraint | Text11 | Text12 | Text13 | Text14 | Text16 | Text28 | Text23 |
| --- | --- | --- | --- | --- | --- | --- | --- | --- | --- | --- | --- | --- | --- | --- | --- | --- | --- | --- | --- |
| 244 | 5.1.3.3 | **FM 1** |  | 0d | 2003-06-30 A | 2003-06-30 A |  | 100% | 2003-06-30 | 2003-06-30 | 0d |  | STEREO | IMPACT | SEP Package | LET | LET | CIT |  |
| 245 | 5.1.3.3.1 | Rework/haywire/trim LET FM 1 MISC Board | milestone | 0d | 2003-06-30 A | 2003-06-30 A | 264 | 100% | 2003-06-30 | 2003-06-30 | 0d |  | STEREO | IMPACT | SEP Package | LET | LET | CIT |  |
| 246 | 5.1.3.3.2 | Post-rework QA inspection for LET FM 1 MISC Board | milestone | 0d | 2003-06-30 A | 2003-06-30 A | 245 | 100% | 2003-06-30 | 2003-06-30 | 0d |  | STEREO | IMPACT | SEP Package | LET | LET | CIT |  |
| 247 | 5.1.3.4 | **FM 2** |  | 0d | 2003-06-30 A | 2003-06-30 A |  | 100% | 2003-06-30 | 2003-06-30 | 0d |  | STEREO | IMPACT | SEP Package | LET | LET | CIT |  |
| 248 | 5.1.3.4.1 | Rework/haywire/trim LET FM 2 MISC Board | milestone | 0d | 2003-06-30 A | 2003-06-30 A | 272 | 100% | 2003-06-30 | 2003-06-30 | 0d |  | STEREO | IMPACT | SEP Package | LET | LET | CIT |  |
| 249 | 5.1.3.4.2 | Post-rework QA inspection for LET FM 2 MISC Board | milestone | 0d | 2003-06-30 A | 2003-06-30 A | 248FS-1d | 100% | 2003-06-30 | 2003-06-30 | 0d |  | STEREO | IMPACT | SEP Package | LET | LET | CIT |  |
| 250 | 5.1.4 | **Assembly** |  | 0d | 2003-06-30 A | 2003-06-30 A |  | 100% | 2003-06-30 | 2003-06-30 | 0d |  | STEREO | IMPACT | SEP Package | LET | LET | CIT |  |
| 251 | 5.1.4.1 | **ETU** |  | 0d | 2003-06-30 A | 2003-06-30 A |  | 100% | 2003-06-30 | 2003-06-30 | 0d |  | STEREO | IMPACT | SEP Package | LET | LET | CIT |  |
| 252 | 5.1.4.1.1 | Assemble EM LET MISC Board | milestone | 0d | 2003-06-30 A | 2003-06-30 A | 231, 230, 229, 233 | 100% | 2003-06-30 | 2003-06-30 | 0d | start no earlier than 2003-06-30 | STEREO | IMPACT | SEP Package | LET | LET | CIT | (obsolete)EM MISC Board Assembled |
| 253 | 5.1.4.2 | **FM 1** |  | 0d | 2003-06-30 A | 2003-06-30 A |  | 100% | 2003-06-30 | 2003-06-30 | 0d |  | STEREO | IMPACT | SEP Package | LET | LET | CIT |  |
| 254 | 5.1.4.2.1 | Assemble FM 1 Let MISC Board | milestone | 0d | 2003-06-30 A | 2003-06-30 A | 238, 239, 240, 241, 243 | 100% | 2003-06-30 | 2003-06-30 | 0d |  | STEREO | IMPACT | SEP Package | LET | LET | CIT |  |
| 255 | 5.1.4.2.2 | Post-assembly QA inpection for LET FM 1 MISC Board | milestone | 0d | 2003-06-30 A | 2003-06-30 A | 254 | 100% | 2003-06-30 | 2003-06-30 | 0d |  | STEREO | IMPACT | SEP Package | LET | LET | CIT | (obsolete)FM 1 MISC Board Assembled |
| 256 | 5.1.4.3 | **FM 2** |  | 0d | 2003-06-30 A | 2003-06-30 A |  | 100% | 2003-06-30 | 2003-06-30 | 0d |  | STEREO | IMPACT | SEP Package | LET | LET | CIT |  |
| 257 | 5.1.4.3.1 | Assemble FM 2 LET MISC Board | milestone | 0d | 2003-06-30 A | 2003-06-30 A | 241, 238, 239, 240, 243 | 100% | 2003-06-30 | 2003-06-30 | 0d |  | STEREO | IMPACT | SEP Package | LET | LET | CIT |  |
| 258 | 5.1.4.3.2 | Post-assembly QA inspection for LET FM 2 MISC Board | milestone | 0d | 2003-06-30 A | 2003-06-30 A | 257 | 100% | 2003-06-30 | 2003-06-30 | 0d |  | STEREO | IMPACT | SEP Package | LET | LET | CIT | (obsolete)FM 2 MISC Board Assembled |
| 259 | 5.1.5 | **Test** |  | 0d | 2003-06-30 A | 2003-06-30 A |  | 100% | 2003-06-30 | 2003-06-30 | 0d |  | STEREO | IMPACT | SEP Package | LET | LET | CIT |  |
| 260 | 5.1.5.1 | **ETU** |  | 0d | 2003-06-30 A | 2003-06-30 A |  | 100% | 2003-06-30 | 2003-06-30 | 0d |  | STEREO | IMPACT | SEP Package | LET | LET | CIT |  |
| 261 | 5.1.5.1.1 | Test EM LET MISC Board | milestone | 0d | 2003-06-30 A | 2003-06-30 A | 252, 379 | 100% | 2003-06-30 | 2003-06-30 | 0d | start no earlier than 2003-06-30 | STEREO | IMPACT | SEP Package | LET | LET | CIT | (obsolete)EM MISC Board Tested |
| 262 | 5.1.5.1.2 | Doc EM LET MISC Board test results | milestone | 0d | 2003-06-30 A | 2003-06-30 A | 261 | 100% | 2003-06-30 | 2003-06-30 | 0d |  | STEREO | IMPACT | SEP Package | LET | LET | CIT |  |
| 263 | 5.1.5.2 | **FM 1** |  | 0d | 2003-06-30 A | 2003-06-30 A |  | 100% | 2003-06-30 | 2003-06-30 | 0d |  | STEREO | IMPACT | SEP Package | LET | LET | CIT |  |
| 264 | 5.1.5.2.1 | Test FM 1 LET MISC Board (initial) | milestone | 0d | 2003-06-30 A | 2003-06-30 A | 255, 380 | 100% | 2003-06-30 | 2003-06-30 | 0d |  | STEREO | IMPACT | SEP Package | LET | LET | CIT |  |
| 265 | 5.1.5.2.2 | Doc FM 1 LET MISC Boards test results | milestone | 0d | 2003-06-30 A | 2003-06-30 A | 264 | 100% | 2003-06-30 | 2003-06-30 | 0d |  | STEREO | IMPACT | SEP Package | LET | LET | CIT |  |
| 266 | 5.1.5.2.3 | Stake/conformal coat FM 1 LET MISC Boards | milestone | 0d | 2003-06-30 A | 2003-06-30 A | 223 | 100% | 2003-06-30 | 2003-06-30 | 0d |  | STEREO | IMPACT | SEP Package | LET | LET | CIT |  |
| 267 | 5.1.5.2.4 | Bakeout FM 1 LET MISC Boards | milestone | 0d | 2003-06-30 A | 2003-06-30 A | 266 | 100% | 2003-06-30 | 2003-06-30 | 0d |  | STEREO | IMPACT | SEP Package | LET | LET | CIT |  |
| 268 | 5.1.5.2.5 | Post-conf. Coat QA inspection for FM 1 LET MISC Board | milestone | 0d | 2003-06-30 A | 2003-06-30 A | 267 | 100% | 2003-06-30 | 2003-06-30 | 0d |  | STEREO | IMPACT | SEP Package | LET | LET | CIT |  |
| 269 | 5.1.5.2.6 | Test LET FM 1 MISC Board (final) | milestone | 0d | 2003-06-30 A | 2003-06-30 A | 268 | 100% | 2003-06-30 | 2003-06-30 | 0d |  | STEREO | IMPACT | SEP Package | LET | LET | CIT | (obsolete)FM 1 MISC Board Tested |
| 270 | 5.1.5.2.7 | Mass properties/photo for LET FM 1 MISC Board | milestone | 0d | 2003-06-30 A | 2003-06-30 A | 269 | 100% | 2003-06-30 | 2003-06-30 | 0d |  | STEREO | IMPACT | SEP Package | LET | LET | CIT |  |

| ID | WBS | Task | Type | Duration | Start | Finish | Predecessors | Complete | Remaining | Baseline start | Baseline finish | Baseline duration | Total slack | Free slack | Constraint | Text11 | Text12 | Text13 | Text14 | Text16 | Text28 | Text23 | Text21 |
| --- | --- | --- | --- | --- | --- | --- | --- | --- | --- | --- | --- | --- | --- | --- | --- | --- | --- | --- | --- | --- | --- | --- | --- |
| 271 | 5.1.5.3 | **FM 1 & FM 2** |  | 0d | 2003-06-30 A | 2003-06-30 A |  | 100% |  | 2003-06-30 | 2003-06-30 | 0d |  |  |  | STEREO | IMPACT | SEP Package | LET | LET | CIT |  |  |
| 272 | 5.1.5.3.1 | Test FM 2 LET MISC Board (initial) | milestone | 0d | 2003-06-30 A | 2003-06-30 A | 258, 380 | 100% |  | 2003-06-30 | 2003-06-30 | 0d |  |  |  | STEREO | IMPACT | SEP Package | LET | LET | CIT |  |  |
| 273 | 5.1.5.3.2 | Doc FM 2 LET MISC Boards test results | milestone | 0d | 2003-06-30 A | 2003-06-30 A | 272 | 100% |  | 2003-06-30 | 2003-06-30 | 0d |  |  |  | STEREO | IMPACT | SEP Package | LET | LET | CIT |  |  |
| 274 | 5.1.5.3.3 | Stake/conformal coat FM 2 LET MISC Board | milestone | 0d | 2003-06-30 A | 2003-06-30 A | 223 | 100% |  | 2003-06-30 | 2003-06-30 | 0d |  |  |  | STEREO | IMPACT | SEP Package | LET | LET | CIT |  |  |
| 275 | 5.1.5.3.4 | Bakeout FM 2 LET MISC Boards | milestone | 0d | 2003-06-30 A | 2003-06-30 A | 274 | 100% |  | 2003-06-30 | 2003-06-30 | 0d |  |  |  | STEREO | IMPACT | SEP Package | LET | LET | CIT |  |  |
| 276 | 5.1.5.3.5 | Post-conf. Coat QA inspection for FM 2 LET MISC Board | milestone | 0d | 2003-06-30 A | 2003-06-30 A | 275 | 100% |  | 2003-06-30 | 2003-06-30 | 0d |  |  |  | STEREO | IMPACT | SEP Package | LET | LET | CIT |  |  |
| 277 | 5.1.5.3.6 | Test LET FM 2 MISC Board (final) | milestone | 0d | 2003-06-30 A | 2003-06-30 A | 276 | 100% |  | 2003-06-30 | 2003-06-30 | 0d |  |  |  | STEREO | IMPACT | SEP Package | LET | LET | CIT | (obsolete)FM 2 MISC Board Tested |  |
| 278 | 5.1.5.3.7 | Mass properties/photo for LET FM 2 MISC Boards | milestone | 0d | 2003-06-30 A | 2003-06-30 A | 277FS-1d | 100% |  | 2003-06-30 | 2003-06-30 | 0d |  |  |  | STEREO | IMPACT | SEP Package | LET | LET | CIT |  |  |
| 279 | 5.1.5.4 | **FM 1 & FM 2** |  | 0d | 2003-06-30 A | 2003-06-30 A |  | 100% |  | 2003-06-30 | 2003-06-30 | 0d |  |  |  | STEREO | IMPACT | SEP Package | LET | LET | CIT |  |  |
| 280 | 5.1.5.4.1 | Maintain hard copy docs for LET MISC Board | milestone | 0d | 2003-06-30 A | 2003-06-30 A | 278, 270 | 100% |  | 2003-06-30 | 2003-06-30 | 0d |  |  |  | STEREO | IMPACT | SEP Package | LET | LET | CIT |  |  |
| 281 | 6 | **Detector/MISC Board** |  | 542d | 2001-12-03 A | 2004-01-30 |  | 57% | 233.4d | 2001-12-03 | 2004-01-30 | 542d | 212d |  |  | STEREO | IMPACT | SEP Package | LET | LET | CIT |  |  |
| 282 | 6.1 | **Design, Fabrication, Assembly and Test** |  | 542d | 2001-12-03 A | 2004-01-30 |  | 57% | 233.4d | 2001-12-03 | 2004-01-30 | 542d | 212d |  |  | STEREO | IMPACT | SEP Package | LET | LET | CIT |  |  |
| 283 | 6.1.1 | **Procurements** |  | 470d | 2001-12-03 A | 2003-10-15 |  | 84% | 73.73d | 2001-12-03 | 2003-10-15 | 470d | 27d |  |  | STEREO | IMPACT | SEP Package | LET | LET | CIT |  |  |
| 284 | 6.1.1.1 | **ETU** |  | 356.5d | 2001-12-03 A | 2003-05-05 A |  | 100% |  | 2001-12-03 | 2003-05-05 | 356.5d |  |  |  | STEREO | IMPACT | SEP Package | LET | LET | CIT |  |  |
| 285 | 6.1.1.1.1 | Procure LET Detector Board Actel 54SX72A FPGA - EM | milestone | 0d | 2001-12-03 A | 2003-01-22 A |  | 100% |  | 2001-12-03 | 2003-01-22 | 0d |  |  | finish no earlier than 2002-08-01 | STEREO | IMPACT | SEP Package | LET | LET | CIT |  | SRAM EM Proc. |
| 286 | 6.1.1.1.2 | Procure LET Detector Board SRAM 128K x 8, 3.3V - EM |  | 28d | 2002-07-01 A | 2003-01-10 A |  | 100% |  | 2002-07-01 | 2003-01-10 | 28d |  |  | finish no earlier than 2002-08-01 | STEREO | IMPACT | SEP Package | LET | LET | CIT |  |  |
| 287 | 6.1.1.1.3 | Procure LET Detector Board EEPROM 128K x 8, 3.3V - EM |  | 1d | 2002-07-01 A | 2002-08-01 A |  | 100% |  | 2002-07-01 | 2002-08-01 | 1d |  |  | finish no earlier than 2002-08-01 | STEREO | IMPACT | SEP Package | LET | LET | CIT |  |  |
| 288 | 6.1.1.1.4 | Procure LET Detector Board Detector Board EM Parts |  | 10d | 2003-03-03 A | 2003-03-14 A | 300, 301 | 100% |  | 2003-03-03 | 2003-03-14 | 10d |  |  | start no earlier than 2003-03-03 | STEREO | IMPACT | SEP Package | LET | LET | CIT |  |  |
| 289 | 6.1.1.1.5 | Procure LET Detector Board EM PCB |  | 2d | 2003-05-01 A | 2003-05-05 A | 305 | 100% |  | 2003-05-01 | 2003-05-05 | 2d |  |  | start no earlier than 2003-04-30 | STEREO | IMPACT | SEP Package | LET | LET | CIT |  |  |
| 290 | 6.1.1.2 | **FM 1 & FM 2** |  | 325d | 2002-07-01 A | 2003-10-15 |  | 20% | 260d | 2002-07-01 | 2003-10-15 | 325d | 27d |  |  | STEREO | IMPACT | SEP Package | LET | LET | CIT |  |  |
| 291 | 6.1.1.2.1 | Procure LET Detector Board Actel RTSX72S FPGA - flight |  | 1d | 2002-07-01 A | 2002-07-01 A |  | 100% |  | 2002-07-01 | 2002-07-01 | 1d |  |  | start no earlier than 2002-07-01 | STEREO | IMPACT | SEP Package | LET | LET | CIT |  |  |
| 292 | 6.1.1.2.2 | Procure LET Detector Board SRAM 128K x 8, 3.3V - flight | milestone | 0d | 2002-07-01 A | 2003-03-31 A |  | 100% |  | 2002-07-01 | 2003-03-31 | 0d |  |  | finish no earlier than 2002-08-01 | STEREO | IMPACT | SEP Package | LET | LET | CIT |  |  |
| 293 | 6.1.1.2.3 | Procure LET Detector Board EEPROM 128K x 8, 3.3V - flight |  | 1d | 2002-07-01 A | 2002-08-01 A |  | 100% |  | 2002-07-01 | 2002-08-01 | 1d |  |  | finish no earlier than 2002-08-01 | STEREO | IMPACT | SEP Package | LET | LET | CIT |  |  |
| 294 | 6.1.1.2.4 | Procure LET Detector Board Flight Parts |  | 5d | 2003-09-15 | 2003-09-19 | 352 |  |  | 2003-09-15 | 2003-09-19 | 5d | 14d | 0d |  | STEREO | IMPACT | SEP Package | LET | LET | CIT |  |  |
| 295 | 6.1.1.2.5 | Procure flight LET Detector Printed Circuit Board |  | 3d | 2003-10-13 | 2003-10-15 | 312 |  |  | 2003-10-13 | 2003-10-15 | 3d | 27d | 0d |  | STEREO | IMPACT | SEP Package | LET | LET | CIT |  |  |

Notes:
- 288: 20% MS Project Problem
- 289: Dropped succ SS with 197
- 291: Need Activities from Antonio related to decision to have GSFC procure.
- 294: 25% MS project problem

| ID | WBS | Task | Duration | Start | Finish | Predecessors | Complete | Remaining | Baseline start | Baseline finish | Baseline duration | Total slack | Free slack | Constraint | Text11 | Text12 | Text13 | Text14 | Text16 | Text28 | Text23 |
| --- | --- | --- | --- | --- | --- | --- | --- | --- | --- | --- | --- | --- | --- | --- | --- | --- | --- | --- | --- | --- | --- |
| 296 | 6.1.2 | **Design** | 389d | 2002-07-02 A | 2004-01-21 |  | 76% | 92.33d | 2002-07-02 | 2004-01-21 | 389d | 34d |  |  | STEREO | IMPACT | SEP Package | LET | LET | CIT |  |
| 297 | 6.1.2.1 | **ETU** | 305d | 2002-07-02 A | 2003-09-17 |  | 99% | 2.48d | 2002-07-02 | 2003-09-17 | 305d | 27d |  |  | STEREO | IMPACT | SEP Package | LET | LET | CIT |  |
| 298 | 6.1.2.1.1 | Design & sketch LET Detector Printed Circuit Board schematics for EM | 59.1d | 2002-07-02 A | 2002-12-09 A | 94FS+126d | 100% |  | 2002-07-02 | 2002-12-09 | 59.1d |  |  | start no earlier than 2002-07-01 | STEREO | IMPACT | SEP Package | LET | LET | CIT |  |
| 299 | 6.1.2.1.2 | Design LET Detector Printed Circuit Board schematics for EM version | 5d | 2002-12-10 A | 2002-12-16 A | 298 | 100% |  | 2002-12-10 | 2002-12-16 | 5d |  |  | start no earlier than 2002-11-30 | STEREO | IMPACT | SEP Package | LET | LET | CIT |  |
| 300 | 6.1.2.1.3 | Design FPGA Schematics/EEPROM for LET Detector Board EM | 18d | 2002-12-17 A | 2003-01-14 A | 299 | 100% |  | 2002-12-17 | 2003-01-14 | 18d |  |  | start no earlier than 2002-11-30 | STEREO | IMPACT | SEP Package | LET | LET | CIT |  |
| 301 | 6.1.2.1.4 | FMA/design review/risk assessment for LET Detector Board | 5d | 2003-01-15 A | 2003-01-21 A | 299, 300 | 100% |  | 2003-01-15 | 2003-01-21 | 5d |  |  |  | STEREO | IMPACT | SEP Package | LET | LET | CIT |  |
| 302 | 6.1.2.1.5 | Assess LET Detector Board EM and Flight Parts | 14d | 2002-12-17 A | 2003-01-07 A | 299 | 100% |  | 2002-12-17 | 2003-01-07 | 14d |  |  | start no earlier than 2002-11-30 | STEREO | IMPACT | SEP Package | LET | LET | CIT |  |
| 303 | 6.1.2.1.6 | Obtain samples & Footprints, provide to LET Detector Printed Circuit Board designer | 5d | 2003-01-08 A | 2003-01-15 A | 302 | 100% |  | 2003-01-08 | 2003-01-15 | 5d |  |  |  | STEREO | IMPACT | SEP Package | LET | LET | CIT |  |
| 304 | 6.1.2.1.7 | Design EM LET Detector Printed Circuit Board layout | 15d | 2003-02-20 A | 2003-04-01 A | 301, 299FS+20d, 303 | 100% |  | 2003-02-20 | 2003-04-01 | 15d |  |  |  | STEREO | IMPACT | SEP Package | LET | LET | CIT |  |
| 305 | 6.1.2.1.8 | Review & approve EM LET Detector Printed Circuit Board layout | 1d | 2003-04-02 A | 2003-05-01 A | 304 | 100% |  | 2003-04-02 | 2003-05-01 | 1d |  |  | start no earlier than 2003-03-31 | STEREO | IMPACT | SEP Package | LET | LET | CIT | EM Detector Board Designed |
| 306 | 6.1.2.1.9 | Doc EM LET Detector Board rework (traveler, ECR) | 1d | 2003-09-17 | 2003-09-17 | 326 |  |  | 2003-09-17 | 2003-09-17 | 1d | 27d | 0d |  | STEREO | IMPACT | SEP Package | LET | LET | CIT |  |
| 307 | 6.1.2.2 | **FM 1 & FM 2** | 84d | 2003-09-18 | 2004-01-21 |  |  |  | 2003-09-18 | 2004-01-21 | 84d | 27d |  |  | STEREO | IMPACT | SEP Package | LET | LET | CIT |  |
| 308 | 6.1.2.2.1 | Revise/update LET Detector Printed Circuit Board schematics for flight version | 10d | 2003-09-18 | 2003-10-01 | 306, 355 |  |  | 2003-09-18 | 2003-10-01 | 10d | 27d | 0d |  | STEREO | IMPACT | SEP Package | LET | LET | CIT |  |
| 309 | 6.1.2.2.2 | Revise/update FPGA Schematics/EEPROM for LET Detector Board Flight Version | 10d | 2003-09-18 | 2003-10-01 | 306, 355 |  |  | 2003-09-18 | 2003-10-01 | 10d | 27d | 0d |  | STEREO | IMPACT | SEP Package | LET | LET | CIT |  |
| 310 | 6.1.2.2.3 | Obtain samples & Footprints, provide to LET Detector Printed Circuit Board designer | 7d | 2003-09-22 | 2003-09-30 | 294 |  |  | 2003-09-22 | 2003-09-30 | 7d | 28d | 1d |  | STEREO | IMPACT | SEP Package | LET | LET | CIT |  |
| 311 | 6.1.2.2.4 | Revise/update LET Detector Printed Circuit Board layout for flight version | 4d | 2003-10-02 | 2003-10-08 | 308, 309, 310 |  |  | 2003-10-02 | 2003-10-08 | 4d | 27d | 0d |  | STEREO | IMPACT | SEP Package | LET | LET | CIT |  |
| 312 | 6.1.2.2.5 | Review & approve flight LET Detector Printed Circuit Board layout | 2d | 2003-10-09 | 2003-10-10 | 311 |  |  | 2003-10-09 | 2003-10-10 | 2d | 27d | 0d |  | STEREO | IMPACT | SEP Package | LET | LET | CIT | Flight Detector Board Design Rework |
| 313 | 6.1.2.2.6 | Doc flight LET Detector Board rework (traveler, ECR) Board 1 | 1d | 2004-01-14 | 2004-01-14 | 343 |  |  | 2004-01-08 | 2004-01-08 | 1d | 20d | 0d |  | STEREO | IMPACT | SEP Package | LET | LET | CIT |  |
| 314 | 6.1.2.2.7 | Final update of LET Detector Printed Circuit Board 1 schematics & layout | 1d | 2004-01-15 | 2004-01-15 | 313 |  |  | 2004-01-09 | 2004-01-09 | 1d | 20d | 6d |  | STEREO | IMPACT | SEP Package | LET | LET | CIT |  |
| 315 | 6.1.2.2.8 | Doc flight LET Detector Board rework (traveler, ECR) Board 2 | 1d | 2004-01-20 | 2004-01-20 | 348 |  |  | 2004-01-20 | 2004-01-20 | 1d | 34d | 0d |  | STEREO | IMPACT | SEP Package | LET | LET | CIT |  |
| 316 | 6.1.2.2.9 | Final update of LET Detector Printed Circuit Board 2 schematics & layout | 1d | 2004-01-21 | 2004-01-21 | 315 |  |  | 2004-01-21 | 2004-01-21 | 1d | 34d | 6d |  | STEREO | IMPACT | SEP Package | LET | LET | CIT |  |
| 317 | 6.1.3 | **Fabrication** | 171d | 2003-04-01 A | 2003-12-03 |  | 47% | 91.47d | 2003-04-01 | 2003-12-03 | 171d | 14d |  |  | STEREO | IMPACT | SEP Package | LET | LET | CIT |  |
| 318 | 6.1.3.1 | **ETU** | 118d | 2003-04-01 A | 2003-09-16 |  | 90% | 11.24d | 2003-04-01 | 2003-09-16 | 118d | 27d |  |  | STEREO | IMPACT | SEP Package | LET | LET | CIT |  |
| 319 | 6.1.3.1.1 | Receive/inspect/database EM parts for LET Detector Board | 7d | 2003-04-01 A | 2003-07-01 A | 288FS+10d | 100% |  | 2003-04-01 | 2003-07-01 | 7d |  |  | start no earlier than 2003-03-31 | STEREO | IMPACT | SEP Package | LET | LET | CIT |  |
| 320 | 6.1.3.1.2 | Inspect EM PCB LET Detector Printed Circuit Board | 1d | 2003-05-19 A | 2003-05-20 A | 289FS+10d | 100% |  | 2003-05-19 | 2003-05-20 | 1d |  |  | start no earlier than 2003-04-30 | STEREO | IMPACT | SEP Package | LET | LET | CIT | EM Detector Board Fabricated |
| 321 | 6.1.3.1.3 | Generate EM kit list in database for LET Detector Board | 2d | 2003-04-10 A | 2003-04-11 A | 319 | 100% |  | 2003-04-10 | 2003-04-11 | 2d |  |  |  | STEREO | IMPACT | SEP Package | LET | LET | CIT |  |
| 322 | 6.1.3.1.4 | Burn in EM FPGA/EEPROM for LET Detector Board | 2d | 2003-04-10 A | 2003-07-01 A | 300, 319 | 100% |  | 2003-04-10 | 2003-07-01 | 2d |  |  |  | STEREO | IMPACT | SEP Package | LET | LET | CIT |  |
| 323 | 6.1.3.1.5 | Bend leads on EM ICs for LET Detector Board | 1d | 2003-04-10 A | 2003-07-01 A | 319 | 100% |  | 2003-04-10 | 2003-07-01 | 1d |  |  |  | STEREO | IMPACT | SEP Package | LET | LET | CIT |  |
| 324 | 6.1.3.1.6 | Generate EM kit book for LET Detector Board | 2d | 2003-04-14 A | 2003-04-15 A | 321 | 100% |  | 2003-04-14 | 2003-04-15 | 2d |  |  |  | STEREO | IMPACT | SEP Package | LET | LET | CIT |  |
| 325 | 6.1.3.1.7 | Kit EM parts for LET Detector Board | 4d | 2003-04-29 A | 2003-07-01 A | 324FS-1d, 285FS+30d, 286FS+30d, 287FS+30d, 102, 103, 126 | 100% |  | 2003-04-29 | 2003-07-01 | 4d |  |  |  | STEREO | IMPACT | SEP Package | LET | LET | CIT |  |
| 326 | 6.1.3.1.8 | Rework/haywire/trim EM LET Detector Board | 2d | 2003-09-15 | 2003-09-16 | 352 |  |  | 2003-09-15 | 2003-09-16 | 2d | 27d | 0d |  | STEREO | IMPACT | SEP Package | LET | LET | CIT |  |

Notes:
- 302: at 50% MS project problem
- 303: 10% MS Project Problem.

| ID | WBS | Task | Duration | Start | Finish | Predecessors | Complete | Remaining | Baseline start | Baseline finish | Baseline duration | Total slack | Free slack | Constraint | Text11 | Text12 | Text13 | Text14 | Text16 | Text28 | Text23 |
| --- | --- | --- | --- | --- | --- | --- | --- | --- | --- | --- | --- | --- | --- | --- | --- | --- | --- | --- | --- | --- | --- |
| 327 | 6.1.3.2 | **FM 1 & FM 2** | 85d | 2003-08-01 A | 2003-12-03 |  | 32% | 57.54d | 2003-08-01 | 2003-12-03 | 85d | 14d |  |  | STEREO | IMPACT | SEP Package | LET | LET | CIT |  |
| 328 | 6.1.3.2.1 | Receive/inspect/database flight parts for LET Detector Board | 7d | 2003-11-17 | 2003-11-25 | 294FS+38d |  |  | 2003-11-17 | 2003-11-25 | 7d | 14d | 0d |  | STEREO | IMPACT | SEP Package | LET | LET | CIT |  |
| 329 | 6.1.3.2.2 | Inspect flight LET Detector Printed Circuit Boards (coupons & elec continuity) | 2d | 2003-11-12 | 2003-11-13 | 295FS+18d |  |  | 2003-11-12 | 2003-11-13 | 2d | 27d | 13d |  | STEREO | IMPACT | SEP Package | LET | LET | CIT | Flight Detector Boards Fabricated & Inspected |
| 330 | 6.1.3.2.3 | Generate flight kit list in database for LET Detector Board | 1d | 2003-11-26 | 2003-11-26 | 328 |  |  | 2003-11-26 | 2003-11-26 | 1d | 14d | 0d |  | STEREO | IMPACT | SEP Package | LET | LET | CIT |  |
| 331 | 6.1.3.2.4 | Rescreen heritage flight parts for LET Detector Board | 48d | 2003-08-01 A | 2003-10-09 | 302 | 44% | 27d | 2003-08-01 | 2003-10-09 | 48d | 51d | 37d | start no earlier than 2003-08-01 | STEREO | IMPACT | SEP Package | LET | LET | CIT |  |
| 332 | 6.1.3.2.5 | Burn-in flight FPGA/EEPROM for LET Detector Board | 1d | 2003-11-26 | 2003-11-26 | 328, 308 |  |  | 2003-11-26 | 2003-11-26 | 1d | 18d | 4d |  | STEREO | IMPACT | SEP Package | LET | LET | CIT |  |
| 333 | 6.1.3.2.6 | Bend leads on flight ICs for LET Detector Board | 2d | 2003-11-26 | 2003-11-28 | 328, 312 |  |  | 2003-11-26 | 2003-11-28 | 2d | 17d | 3d |  | STEREO | IMPACT | SEP Package | LET | LET | CIT |  |
| 334 | 6.1.3.2.7 | Generate flight kit book for LET Detector Board | 2d | 2003-11-28 | 2003-12-01 | 330 |  |  | 2003-11-28 | 2003-12-01 | 2d | 14d | 0d |  | STEREO | IMPACT | SEP Package | LET | LET | CIT |  |
| 335 | 6.1.3.2.8 | Kit flight parts for LET Detector Boards | 2d | 2003-12-02 | 2003-12-03 | 334, 291, 292, 293, 131, 135 |  |  | 2003-12-02 | 2003-12-03 | 2d | 14d | 0d |  | STEREO | IMPACT | SEP Package | LET | LET | CIT |  |
| 336 | 6.1.4 | **Assembly** | 115d | 2003-08-01 A | 2004-01-19 |  | 4% | 110.58d | 2003-08-01 | 2004-01-19 | 115d | 28d |  |  | STEREO | IMPACT | SEP Package | LET | LET | CIT |  |
| 337 | 6.1.4.1 | **ETU** | 1d | 2003-08-01 A | 2003-08-01 A |  | 100% |  | 2003-08-01 | 2003-08-01 | 1d |  |  |  | STEREO | IMPACT | SEP Package | LET | LET | CIT |  |
| 338 | 6.1.4.1.1 | Assemble EM LET Detector Board (Final Part) | 1d | 2003-08-01 A | 2003-08-01 A | 320, 322, 323, 325 | 100% |  | 2003-08-01 | 2003-08-01 | 1d |  |  | start no earlier than 2003-08-01 | STEREO | IMPACT | SEP Package | LET | LET | CIT | EM Detector Board Assembled |
| 339 | 6.1.4.2 | **FM 1** | 26d | 2003-12-04 | 2004-01-13 |  |  |  | 2003-12-04 | 2004-01-07 | 23d | 14d |  |  | STEREO | IMPACT | SEP Package | LET | LET | CIT |  |
| 340 | 6.1.4.2.1 | Assemble LET FM 1 Detector Board | 10d | 2003-12-04 | 2003-12-17 | 329, 331, 332, 333, 335 |  |  | 2003-12-04 | 2003-12-17 | 10d | 14d | 0d |  | STEREO | IMPACT | SEP Package | LET | LET | CIT |  |
| 341 | 6.1.4.2.2 | Post-assembly QA inspection for flight LET Detector Boards | 1d | 2003-12-18 | 2003-12-18 | 340 |  |  | 2003-12-18 | 2003-12-18 | 1d | 14d | 0d |  | STEREO | IMPACT | SEP Package | LET | LET | CIT | FM 1 Detector Board Assembled |
| 342 | 6.1.4.2.3 | Rework/haywire/trim flight LET Detector Boards | 1d | 2004-01-09 | 2004-01-09 | 357, 358 |  |  | 2004-01-06 | 2004-01-06 | 1d | 14d | 0d |  | STEREO | IMPACT | SEP Package | LET | LET | CIT |  |
| 343 | 6.1.4.2.4 | Post-rework QA inspection for LET Detector Boards | 1d | 2004-01-13 | 2004-01-13 | 342 |  |  | 2004-01-07 | 2004-01-07 | 1d | 14d | 0d |  | STEREO | IMPACT | SEP Package | LET | LET | CIT |  |
| 344 | 6.1.4.3 | **FM 2** | 20d | 2003-12-18 | 2004-01-19 |  |  |  | 2003-12-18 | 2004-01-19 | 20d | 28d |  |  | STEREO | IMPACT | SEP Package | LET | LET | CIT |  |
| 345 | 6.1.4.3.1 | Assemble LET FM 2 Detector Board | 9d | 2003-12-18 | 2003-12-31 | 340 |  |  | 2003-12-18 | 2003-12-31 | 9d | 28d | 0d |  | STEREO | IMPACT | SEP Package | LET | LET | CIT |  |
| 346 | 6.1.4.3.2 | Post-assembly QA inspection for flight LET Detector Boards | 1d | 2004-01-02 | 2004-01-02 | 345 |  |  | 2004-01-02 | 2004-01-02 | 1d | 28d | 0d |  | STEREO | IMPACT | SEP Package | LET | LET | CIT | FM 2 Detector Board Assembled |
| 347 | 6.1.4.3.3 | Rework/haywire/trim flight LET Detector Boards | 1d | 2004-01-16 | 2004-01-16 | 366, 367 |  |  | 2004-01-16 | 2004-01-16 | 1d | 28d | 0d |  | STEREO | IMPACT | SEP Package | LET | LET | CIT |  |
| 348 | 6.1.4.3.4 | Post-rework QA inspection for LET Detector Boards | 1d | 2004-01-19 | 2004-01-19 | 347 |  |  | 2004-01-19 | 2004-01-19 | 1d | 28d | 0d |  | STEREO | IMPACT | SEP Package | LET | LET | CIT |  |
| 349 | 6.1.5 | **Test** | 123d | 2003-08-04 A | 2004-01-30 |  | 27% | 89.76d | 2003-08-04 | 2004-01-30 | 123d | 212d |  |  | STEREO | IMPACT | SEP Package | LET | LET | CIT |  |
| 350 | 6.1.5.1 | **ETU** | 31d | 2003-08-04 A | 2003-09-16 |  | 65% | 11d | 2003-08-04 | 2003-09-16 | 31d | 28d |  |  | STEREO | IMPACT | SEP Package | LET | LET | CIT |  |
| 351 | 6.1.5.1.1 | Test EM LET Detector Board (Initial) | 10d | 2003-08-04 A | 2003-08-15 A | 338 | 100% |  | 2003-08-04 | 2003-08-15 | 10d |  |  | start no earlier than 2003-06-30 | STEREO | IMPACT | SEP Package | LET | LET | CIT | EM Detector Board Tested |
| 352 | 6.1.5.1.2 | Test EM LET Detector Board (Final) | 19d | 2003-08-18 A | 2003-09-12 | 351 | 53% | 9d | 2003-08-18 | 2003-09-12 | 19d | 14d | 0d |  | STEREO | IMPACT | SEP Package | LET | LET | CIT |  |
| 353 | 2.1.6 | Integrate/Test SEP Central EM with Sensors | 5d | 2003-10-07 | 2003-10-13 | 352 |  |  | 2003-10-01 | 2003-10-08 | 5d | 33d | 0d |  | STEREO | IMPACT | SEP Package | LET | LET | CIT |  |
| 354 | 2.1.3 | LET tel EM integration/documentation | 9d | 2003-11-17 | 2003-11-28 | 352 |  |  | 2003-11-17 | 2003-11-28 | 9d | 52d | 38d | start no earlier than 2003-11-17 | STEREO | IMPACT | SEP Package | LET | LET | CIT |  |
| 355 | 6.1.5.1.5 | Doc EM LET Detector Board test results | 2d | 2003-09-15 | 2003-09-16 | 352 |  |  | 2003-09-15 | 2003-09-16 | 2d | 28d | 1d |  | STEREO | IMPACT | SEP Package | LET | LET | CIT |  |

| ID | WBS | Task | Duration | Start | Finish | Predecessors | Complete | Remaining | Baseline start | Baseline finish | Baseline duration | Total slack | Free slack | Constraint | Text11 | Text12 | Text13 | Text14 | Text16 | Text28 | Text23 |
| --- | --- | --- | --- | --- | --- | --- | --- | --- | --- | --- | --- | --- | --- | --- | --- | --- | --- | --- | --- | --- | --- |
| 356 | 6.1.5.2 | **FM 1** | 19d | 2003-12-29 | 2004-01-26 |  |  |  | 2003-12-29 | 2004-01-21 | 16d | 14d |  |  | STEREO | IMPACT | SEP Package | LET | LET | CIT |  |
| 357 | 6.1.5.2.1 | Test LET FM 1 Detector Boards (initial) | 5d | 2003-12-29 | 2004-01-05 | 341FS+5d |  |  | 2003-12-29 | 2004-01-05 | 5d | 14d | 0d |  | STEREO | IMPACT | SEP Package | LET | LET | CIT |  |
| 358 | 6.1.5.2.2 | Doc LET FM 1 Detector Board test results | 3d | 2004-01-06 | 2004-01-08 | 357 |  |  | 2004-01-06 | 2004-01-08 | 3d | 14d | 0d |  | STEREO | IMPACT | SEP Package | LET | LET | CIT |  |
| 359 | 6.1.5.2.3 | Stake/conformal coat LET FM 1 Detector Boards | 1d | 2004-01-14 | 2004-01-14 | 343 |  |  | 2004-01-08 | 2004-01-08 | 1d | 14d | 0d |  | STEREO | IMPACT | SEP Package | LET | LET | CIT |  |
| 360 | 6.1.5.2.4 | Bakeout LET FM 1 Detector Boards | 1d | 2004-01-15 | 2004-01-15 | 359 |  |  | 2004-01-09 | 2004-01-09 | 1d | 14d | 0d |  | STEREO | IMPACT | SEP Package | LET | LET | CIT |  |
| 361 | 6.1.5.2.5 | Post-conf. Coat QA inspection of LET FM 1 Detector Boards | 1d | 2004-01-16 | 2004-01-16 | 360 |  |  | 2004-01-13 | 2004-01-13 | 1d | 14d | 0d |  | STEREO | IMPACT | SEP Package | LET | LET | CIT |  |
| 362 | 6.1.5.2.6 | Test LET FM 1 Detector Boards (final) | 5d | 2004-01-19 | 2004-01-23 | 361 |  |  | 2004-01-14 | 2004-01-20 | 5d | 14d | 0d |  | STEREO | IMPACT | SEP Package | LET | LET | CIT | FM1 Detector Board Tested |
| 363 | 6.1.5.2.7 | LET FM 1 Detector Board Mass properties/photo | 1d | 2004-01-26 | 2004-01-26 | 362, 314 |  |  | 2004-01-21 | 2004-01-21 | 1d | 14d | 0d |  | STEREO | IMPACT | SEP Package | LET | LET | CIT |  |
| 364 | 2.3.3 | LET tel flight 1 integration/documentation | 15d | 2004-01-27 | 2004-02-17 | 363, 90FS-20d |  |  | 2004-01-22 | 2004-02-11 | 15d | 14d | 0d |  | STEREO | IMPACT | SEP Package | LET | LET | CIT |  |
| 365 | 6.1.5.3 | **FM 2** | 19d | 2004-01-05 | 2004-01-30 |  |  |  | 2004-01-05 | 2004-01-30 | 19d | 28d |  |  | STEREO | IMPACT | SEP Package | LET | LET | CIT |  |
| 366 | 6.1.5.3.1 | Test LET FM 2 Detector Boards (initial) | 5d | 2004-01-05 | 2004-01-09 | 346 |  |  | 2004-01-05 | 2004-01-09 | 5d | 28d | 0d |  | STEREO | IMPACT | SEP Package | LET | LET | CIT |  |
| 367 | 6.1.5.3.2 | Doc LET FM 2 Detector Board test results | 3d | 2004-01-13 | 2004-01-15 | 366 |  |  | 2004-01-13 | 2004-01-15 | 3d | 28d | 0d |  | STEREO | IMPACT | SEP Package | LET | LET | CIT |  |
| 368 | 6.1.5.3.3 | Stake/conformal coat LET FM 2 Detector Boards | 1d | 2004-01-20 | 2004-01-20 | 348 |  |  | 2004-01-20 | 2004-01-20 | 1d | 28d | 0d |  | STEREO | IMPACT | SEP Package | LET | LET | CIT |  |
| 369 | 6.1.5.3.4 | Bakeout LET FM 2 Detector Boards | 1d | 2004-01-21 | 2004-01-21 | 368 |  |  | 2004-01-21 | 2004-01-21 | 1d | 28d | 0d |  | STEREO | IMPACT | SEP Package | LET | LET | CIT |  |
| 370 | 6.1.5.3.5 | Post-conf. Coat QA inspection of LET FM 2 Detector Boards | 1d | 2004-01-22 | 2004-01-22 | 369 |  |  | 2004-01-22 | 2004-01-22 | 1d | 28d | 0d |  | STEREO | IMPACT | SEP Package | LET | LET | CIT |  |
| 371 | 6.1.5.3.6 | Test LET FM 2 Detector Boards (final) | 5d | 2004-01-23 | 2004-01-29 | 370 |  |  | 2004-01-23 | 2004-01-29 | 5d | 28d | 0d |  | STEREO | IMPACT | SEP Package | LET | LET | CIT | FM 2 Detector Board Tested |
| 372 | 6.1.5.3.7 | LET FM 2 Detector Board Mass properties/photo | 1d | 2004-01-30 | 2004-01-30 | 371, 316 |  |  | 2004-01-30 | 2004-01-30 | 1d | 28d | 0d |  | STEREO | IMPACT | SEP Package | LET | LET | CIT |  |
| 373 | 2.4.2 | LET tel flight 2 integration/documentation | 10d | 2004-02-18 | 2004-03-02 | 372 |  |  | 2004-02-12 | 2004-02-26 | 10d | 17d | 3d |  | STEREO | IMPACT | SEP Package | LET | LET | CIT |  |
| 374 | 6.1.5.4 | **FM 1 & FM 2** | 9d | 2004-01-20 | 2004-01-30 |  |  |  | 2004-01-20 | 2004-01-30 | 9d | 212d |  |  | STEREO | IMPACT | SEP Package | LET | LET | CIT |  |
| 375 | 6.1.5.4.1 | Maintain hard copy docs for LET Detector Board | 9d | 2004-01-20 | 2004-01-30 | 372FF |  |  | 2004-01-20 | 2004-01-30 | 9d | 212d |  |  | STEREO | IMPACT | SEP Package | LET | LET | CIT |  |
| 376 | 7 | **Flight Software** | 337d | 2002-07-02 A | 2003-11-03 |  | 86% | 46.63d | 2002-07-02 | 2003-11-03 | 337d | 78d |  |  | STEREO | IMPACT | SEP Package | LET | LET | CIT |  |
| 377 | 7.1 | **Design, Manufacture, Assembly and Test** | 337d | 2002-07-02 A | 2003-11-03 |  | 86% | 46.63d | 2002-07-02 | 2003-11-03 | 337d | 78d |  |  | STEREO | IMPACT | SEP Package | LET | LET | CIT |  |
| 378 | 7.1.1 | **Fabrication** | 337d | 2002-07-02 A | 2003-11-03 |  | 86% | 46.63d | 2002-07-02 | 2003-11-03 | 337d | 78d |  |  | STEREO | IMPACT | SEP Package | LET | LET | CIT |  |
| 379 | 7.1.1.1 | LET Flight Software Build 1 | 149d | 2002-07-02 A | 2003-03-05 A | 13 | 100% |  | 2002-07-02 | 2003-03-05 | 149d |  |  | start no earlier than 2002-07-01 | STEREO | IMPACT | SEP Package | LET | LET | CIT | B1 Flight S/W |
| 380 | 7.1.1.2 | Let Flight Software Build 2 | 104d | 2003-03-06 A | 2003-07-31 A | 379 | 100% |  | 2003-03-06 | 2003-07-31 | 104d |  |  | start no earlier than 2003-03-03 | STEREO | IMPACT | SEP Package | LET | LET | CIT | B2 Flight S/W |
| 381 | 7.1.1.3 | Let Flight Software Build 3 | 65d | 2003-08-01 A | 2003-11-03 | 380 | 32% | 44d | 2003-08-01 | 2003-11-03 | 65d | 78d | 0d |  | STEREO | IMPACT | SEP Package | LET | LET | CIT | B3 Flight S/W |

| ID | WBS | Task | Duration | Start | Finish | Predecessors | Baseline start | Baseline finish | Baseline duration | Total slack | Free slack | Text11 | Text12 | Text13 | Text14 | Text16 | Text28 | Text23 |
| --- | --- | --- | --- | --- | --- | --- | --- | --- | --- | --- | --- | --- | --- | --- | --- | --- | --- | --- |
| 382 | 8 | **Integration & Test** | 37d | 2004-01-05 | 2004-02-26 |  | 2004-01-05 | 2004-02-26 | 37d | 1d |  | STEREO | IMPACT | SEP Package | LET | LET | CIT |  |
| 383 | 8.1 | **FM 1** | 37d | 2004-01-05 | 2004-02-26 |  | 2004-01-05 | 2004-02-26 | 37d | 1d |  | STEREO | IMPACT | SEP Package | LET | LET | CIT |  |
| 384 | 8.1.1 | Integrate LET FM 1 Housing With Detectors | 37d | 2004-01-05 | 2004-02-26 | 190, 53, 87, 88, 89, 90 | 2004-01-05 | 2004-02-26 | 37d | 1d | 0d | STEREO | IMPACT | SEP Package | LET | LET | CIT | FM 1 Integrated & Tested |
| 385 | 8.2 | **FM 2** | 37d | 2004-01-05 | 2004-02-26 |  | 2004-01-05 | 2004-02-26 | 37d | 14d |  | STEREO | IMPACT | SEP Package | LET | LET | CIT |  |
| 386 | 8.2.1 | Integrate LET FM 2 Housing With Detectors | 37d | 2004-01-05 | 2004-02-26 | 190, 56, 87, 88, 89, 90 | 2004-01-05 | 2004-02-26 | 37d | 14d | 0d | STEREO | IMPACT | SEP Package | LET | LET | CIT | FM 2 Integrated and Tested |
